# AUV Docking 2005

Schedule from MS Project, 2005-08-01 to 2006-12-15.
MBARI

## Calendars

- Standard: Mon-Fri 08:00-12:00, 13:00-17:00; Sat-Sun off.

## Resources

| Resource |
| --- |
| Lance |
| Brett |
| Thomas |
| Machine shop |
| Jon |
| Lance McBride |
| Thomas Hoover |
| Test Tank |
| Rob McEwen |
| Zephyr |
| Brett Hobson |
| Jon Erickson |
| AUV Fabricator #1 |
| Mike Godin |
| Yanwu Zhang |
| Rich |
| EE |
| SE |
| ME |
| MS |
| RE |
| Bluefin |
| Rob |

## Schedule

| ID | WBS | Task | Duration | Start | Finish | Predecessors | Total slack | Free slack | Constraint | Resources | Work |
| --- | --- | --- | --- | --- | --- | --- | --- | --- | --- | --- | --- |
| 1 | 1 | **AUV Docking** | 359d? | 2005-08-01 | 2006-12-15 |  | 0d |  |  |  | 5724.95h |
| 2 | 1.1 | **2005 Tasks** | 115d? | 2005-08-01 | 2006-01-06 |  | 244d |  |  |  | 1264h |
| 3 | 1.1.1 | Clean up AUV lab | 5d | 2005-08-01 | 2005-08-05 |  | 354d |  |  | Thomas | 40h |
| 4 | 1.1.2 | Define architecture of ME, EE, SE | 1d? | 2005-08-01 | 2005-08-01 |  | 358d |  |  | Jon; Rob; Lance; Thomas; Brett | 40h |
| 5 | 1.1.3 | **AUV Nose Section** | 115d? | 2005-08-01 | 2006-01-06 |  | 244d |  |  |  | 216h |
| 6 | 1.1.3.1 | Clean up ALTEX nose section and prepare to fit it to the DMO mid and tail | 1d? | 2005-08-01 | 2005-08-01 |  | 358d |  |  |  |  |
| 7 | 1.1.3.2 | Assemble unit | 7d | 2005-08-01 | 2005-08-09 |  | 352d |  |  |  |  |
| 8 | 1.1.3.3 | USBL Product Evaluations | 5d | 2005-08-01 | 2005-08-05 |  | 244d | 0d |  | Thomas; Brett | 80h |
| 9 | 1.1.3.4 | Order USBL | 95d | 2005-08-08 | 2005-12-16 | 8 | 244d | 0d |  |  |  |
| 10 | 1.1.3.5 | Design USBL mount in nose cone | 5d? | 2005-12-19 | 2005-12-23 | 9 | 244d | 0d |  | Jon | 40h |
| 11 | 1.1.3.6 | Build USBL mount and assemble nose cone | 5d? | 2005-12-26 | 2005-12-30 | 10 | 244d | 0d |  | Jon | 40h |
| 12 | 1.1.3.7 | Install and test USBL | 5d | 2006-01-02 | 2006-01-06 | 9, 11 | 244d |  |  | Thomas | 40h |
| 13 | 1.1.3.8 | Mount nose cone to CTD midbody/tailcone | 2d? | 2005-08-01 | 2005-08-02 |  | 357d |  |  | Thomas | 16h |
| 14 | 1.1.4 | **Docking Module** | 20d? | 2005-08-01 | 2005-08-26 |  | 339d |  |  |  | 240h |
| 15 | 1.1.4.1 | Design Actuator | 1d? | 2005-08-01 | 2005-08-01 |  | 358d |  |  | Jon | 8h |
| 16 | 1.1.4.2 | Design PV | 1d? | 2005-08-01 | 2005-08-01 |  | 358d |  |  | Jon | 8h |
| 17 | 1.1.4.3 | layout components into 10" module | 1d? | 2005-08-01 | 2005-08-01 |  | 358d |  |  | Jon | 8h |
| 18 | 1.1.4.4 | Assemble BOM for Docking Module | 3d | 2005-08-01 | 2005-08-03 |  | 356d |  |  | Thomas; Jon | 48h |
| 19 | 1.1.4.5 | Order required parts from Bluefin | 1d | 2005-08-01 | 2005-08-01 |  | 358d |  |  | Brett | 8h |
| 20 | 1.1.4.6 | Mfg. Remaining parts | 20d? | 2005-08-01 | 2005-08-26 |  | 339d |  |  | Machine shop | 160h |
| 21 | 1.1.5 | **DTS (Data Transfer System)** | 15d? | 2005-08-01 | 2005-08-19 |  | 344d |  |  | Lance | 192h |
| 22 | 1.1.5.1 | Test of WiFi with omnidirectional antenna | 2d | 2005-08-18 | 2005-08-19 |  | 344d |  | start no earlier than 2005-08-18 | Thomas Hoover; Lance McBride; Test Tank | 24h |
| 23 | 1.1.5.2 | **Test of Wifi with directional antenna and amplifier** | 11.5d | 2005-08-01 | 2005-08-16 |  | 347.5d |  |  |  | 24h |
| 24 | 1.1.5.2.1 | Order materials | 1d | 2005-08-01 | 2005-08-01 |  | 347.5d | 0d |  | Lance McBride | 8h |
| 25 | 1.1.5.2.2 | Shipping time | 5d | 2005-08-02 | 2005-08-08 | 24 | 347.5d | 0d |  |  |  |
| 26 | 1.1.5.2.3 | Manufacture Mount | 1d | 2005-08-08 | 2005-08-12 | 25 | 347.5d | 0d |  | Thomas Hoover; Lance McBride | 8h |
| 27 | 1.1.5.2.4 | Test | 1d | 2005-08-12 | 2005-08-16 | 26 | 347.5d |  |  | Thomas Hoover; Lance McBride; Test Tank | 8h |
| 28 | 1.1.5.3 | Rework and retest | 1d? | 2005-08-01 | 2005-08-01 |  | 358d |  |  | Lance | 8h |
| 29 | 1.1.5.4 | Provide list of hardware integration requirements to ME | 1d? | 2005-08-01 | 2005-08-01 |  | 358d |  |  | Lance | 8h |
| 30 | 1.1.5.5 | Integrate components into Docking module Design | 1d? | 2005-08-01 | 2005-08-01 |  | 358d |  |  | Jon | 8h |

Notes:
- 17: WiFi, ethernet hum, motor driver/amp, IPTS components (rectifier, power supply, battery charger) hall effect sensor electronics

| ID | WBS | Task | Type | Duration | Start | Finish | Predecessors | Total slack | Free slack | Resources | Work |
| --- | --- | --- | --- | --- | --- | --- | --- | --- | --- | --- | --- |
| 31 | 1.1.6 | **IPTS (Inductive Power Transfer System)** |  | 7d? | 2005-08-01 | 2005-08-09 |  | 352d |  |  | 48h |
| 32 | 1.1.6.1 | Validate FAU specs |  | 1d? | 2005-08-01 | 2005-08-01 |  | 358d |  |  |  |
| 33 | 1.1.6.2 | Integrate into Docking Module Design |  | 1d? | 2005-08-01 | 2005-08-01 |  | 358d |  |  |  |
| 34 | 1.1.6.3 | Shipping time |  | 5d | 2005-08-01 | 2005-08-05 |  | 352d | 0d |  |  |
| 35 | 1.1.6.4 | Test power coupling in tank |  | 2d | 2005-08-08 | 2005-08-09 | 34 | 352d |  | Lance McBride; Thomas Hoover; Test Tank | 48h |
| 36 | 1.1.7 | **Dock** |  | 20d? | 2005-08-01 | 2005-08-26 |  | 339d |  |  | 160h |
| 37 | 1.1.7.1 | Design Test Dock |  | 20d | 2005-08-01 | 2005-08-26 |  | 339d |  | Jon | 160h |
| 38 | 1.1.7.2 | Design docking pin receiver |  | 1d? | 2005-08-01 | 2005-08-01 |  | 358d |  |  |  |
| 39 | 1.1.7.3 | Conceptual DR | milestone | 0d | 2005-08-01 | 2005-08-01 |  | 359d |  |  |  |
| 40 | 1.1.8 | **Dock mock-up** |  | 50d? | 2005-08-01 | 2005-10-07 |  | 309d |  |  | 264h |
| 41 | 1.1.8.1 | Dock Design |  | 10d? | 2005-08-01 | 2005-08-12 |  | 309d | 0d | Jon Erickson; Brett Hobson | 160h |
| 42 | 1.1.8.2 | **Long Lead time items** |  | 9d | 2005-08-15 | 2005-08-25 | 41 | 309d |  |  | 16h |
| 43 | 1.1.8.2.1 | Order |  | 1d | 2005-08-15 | 2005-08-15 |  | 309d | 0d | Thomas Hoover | 8h |
| 44 | 1.1.8.2.2 | Shipping time |  | 7d | 2005-08-16 | 2005-08-24 | 43 | 309d | 0d |  |  |
| 45 | 1.1.8.2.3 | Receive |  | 1d | 2005-08-25 | 2005-08-25 | 44 | 309d | 0d | Thomas Hoover | 8h |
| 46 | 1.1.8.3 | **Manufactured parts** |  | 9d | 2005-08-26 | 2005-09-07 | 45 | 309d |  |  | 16h |
| 47 | 1.1.8.3.1 | Order |  | 1d | 2005-08-26 | 2005-08-26 |  | 309d | 0d | Thomas Hoover | 8h |
| 48 | 1.1.8.3.2 | Shipping time |  | 7d | 2005-08-29 | 2005-09-06 | 47 | 309d | 0d |  |  |
| 49 | 1.1.8.3.3 | Receive |  | 1d | 2005-09-07 | 2005-09-07 | 48 | 309d | 0d | Thomas Hoover | 8h |
| 50 | 1.1.8.4 | **Raw material for in-house parts** |  | 9d | 2005-09-08 | 2005-09-20 | 49 | 309d |  |  | 16h |
| 51 | 1.1.8.4.1 | Order |  | 1d | 2005-09-08 | 2005-09-08 |  | 309d | 0d | Thomas Hoover | 8h |
| 52 | 1.1.8.4.2 | Shipping time |  | 7d | 2005-09-09 | 2005-09-19 | 51 | 309d | 0d |  |  |
| 53 | 1.1.8.4.3 | Receive |  | 1d | 2005-09-20 | 2005-09-20 | 52 | 309d | 0d | Thomas Hoover | 8h |
| 54 | 1.1.8.5 | Manufacture in-house parts |  | 7d | 2005-09-21 | 2005-09-29 | 53 | 309d | 0d | Jon Erickson | 56h |
| 55 | 1.1.8.6 | Assemble mock up dock |  | 6d | 2005-09-30 | 2005-10-07 | 54 | 309d |  |  |  |

| ID | WBS | Task | Type | Duration | Start | Finish | Predecessors | Total slack | Free slack | Resources | Work |
| --- | --- | --- | --- | --- | --- | --- | --- | --- | --- | --- | --- |
| 56 | 1.1.9 | **Test AUV with Mock-up in Bay** |  | 1d? | 2005-08-01 | 2005-08-01 |  | 358d |  |  | 64h |
| 57 | 1.1.9.1 | Day 1 of testing |  | 1d? | 2005-08-01 | 2005-08-01 |  | 358d | 0d | Thomas Hoover; Brett Hobson; Mike Godin; Lance McBride; Jon Erickson; Rob McEwen; Yanwu Zhang; Zephyr | 64h |
| 58 | 1.1.10 | Preliminary DR for latching & alignment mechanisms | milestone | 0d | 2005-08-01 | 2005-08-01 | 57 | 358d |  |  |  |
| 60 | 1.2 | **2006:** |  | 359d? | 2005-08-01 | 2006-12-15 |  | 0d |  |  | 4156.95h |
| 61 | 1.2.1 | Fabricate deck cradle with removable wheels |  | 10d? | 2005-08-01 | 2005-08-12 |  | 349d |  | Machine shop | 80h |
| 62 | 1.2.2 | **M1: Latching, power and data transfer** |  | 10d? | 2005-08-01 | 2005-08-12 |  | 349d |  |  | 408h |
| 63 | 1.2.2.1 | **EE tasks** |  | 3d? | 2005-08-01 | 2005-08-03 |  | 356d |  |  | 72h |
| 64 | 1.2.2.1.1 | mount dock electronics in housing |  | 1d? | 2005-08-01 | 2005-08-01 |  | 358d |  | EE | 8h |
| 65 | 1.2.2.1.2 | wire-up and test dock electronics |  | 3d? | 2005-08-01 | 2005-08-03 |  | 356d |  | EE | 24h |
| 66 | 1.2.2.1.3 | install vehicle electronics in housing, wire up and test |  | 3d? | 2005-08-01 | 2005-08-03 |  | 356d |  | EE | 24h |
| 67 | 1.2.2.1.4 | run tests in tank |  | 2d? | 2005-08-01 | 2005-08-02 |  | 357d |  | EE | 16h |
| 68 | 1.2.2.2 | **SE tasks** |  | 3d? | 2005-08-01 | 2005-08-03 |  | 356d |  |  | 48h |
| 69 | 1.2.2.2.1 | write docking actuator control software |  | 2d? | 2005-08-01 | 2005-08-02 |  | 357d |  | SE | 16h |
| 70 | 1.2.2.2.2 | dock detect sensor interface |  | 1d? | 2005-08-01 | 2005-08-01 |  | 358d |  | SE | 8h |
| 71 | 1.2.2.2.3 | integrate IPT control software |  | 3d? | 2005-08-01 | 2005-08-03 |  | 356d |  | SE | 24h |
| 72 | 1.2.2.3 | **ME tasks** |  | 10d? | 2005-08-01 | 2005-08-12 |  | 349d |  |  | 264h |
| 73 | 1.2.2.3.1 | build rev1 docking tube - no cone |  | 3d? | 2005-08-01 | 2005-08-03 |  | 356d |  | ME | 24h |
| 74 | 1.2.2.3.2 | build mockup dock base |  | 3d? | 2005-08-01 | 2005-08-03 |  | 356d |  | ME | 24h |
| 75 | 1.2.2.3.3 | build and test docking actuator |  | 10d? | 2005-08-01 | 2005-08-12 |  | 349d |  | ME | 80h |
| 76 | 1.2.2.3.4 | Design build and mount D-AUV PV |  | 1d? | 2005-08-01 | 2005-08-01 |  | 358d |  |  | 48h |
| 77 | 1.2.2.3.5 | Install in 10" docking section |  | 1d? | 2005-08-01 | 2005-08-01 |  | 358d |  | ME | 8h |
| 78 | 1.2.2.3.6 | assemble mockup vehicle with docking section |  | 1d? | 2005-08-01 | 2005-08-01 |  | 358d |  | ME | 8h |
| 79 | 1.2.2.3.7 | deploy in tank and run tests |  | 6d? | 2005-08-01 | 2005-08-08 |  | 353d |  | ME | 48h |
| 80 | 1.2.2.3.8 | Management |  | 3d? | 2005-08-01 | 2005-08-03 |  | 356d |  | ME | 24h |

Notes:
- 64: RF modem, IPT hardware, IPT hardware controller

| ID | WBS | Task | Type | Duration | Start | Finish | Predecessors | Total slack | Free slack | Constraint | Resources | Work |
| --- | --- | --- | --- | --- | --- | --- | --- | --- | --- | --- | --- | --- |
| 81 | 1.2.2.4 | **MS tasks** |  | 3d? | 2005-08-01 | 2005-08-03 |  | 356d |  |  |  | 24h |
| 82 | 1.2.2.4.1 | Fabricate actuator parts and dock parts |  | 3d? | 2005-08-01 | 2005-08-03 |  | 356d |  |  | MS | 24h |
| 83 | 1.2.3 | **M2: Demo homing accuracy offshore** |  | 184d? | 2005-08-01 | 2006-04-14 |  | 90d | 0d |  |  | 504h |
| 84 | 1.2.3.1 | **EE tasks** |  | 4d? | 2005-08-01 | 2005-08-04 |  | 270d | 180d |  |  | 56h |
| 85 | 1.2.3.1.1 | wire up subsea camera/lights/electronics |  | 3d? | 2005-08-01 | 2005-08-03 |  | 271d |  |  | EE | 24h |
| 86 | 1.2.3.1.2 | Help with tests |  | 4d? | 2005-08-01 | 2005-08-04 |  | 270d |  |  | EE | 32h |
| 87 | 1.2.3.2 | **SE tasks** |  | 13d? | 2005-08-01 | 2005-08-17 |  | 261d |  |  |  | 248h |
| 88 | 1.2.3.2.1 | write and troubleshoot USBL interface |  | 7d? | 2005-08-01 | 2005-08-09 |  | 267d |  |  | SE | 56h |
| 89 | 1.2.3.2.2 | Develop Homing algorithm |  | 13d? | 2005-08-01 | 2005-08-17 |  | 261d |  |  | SE | 104h |
| 90 | 1.2.3.2.3 | Integrate SW into MVP, test and troubleshoot |  | 5d? | 2005-08-01 | 2005-08-05 |  | 269d |  |  | SE | 40h |
| 91 | 1.2.3.2.4 | tank test |  | 2d? | 2005-08-01 | 2005-08-02 |  | 272d |  |  | SE | 16h |
| 92 | 1.2.3.2.5 | perform offshore tests |  | 4d? | 2005-08-01 | 2005-08-04 |  | 270d |  |  | SE | 32h |
| 93 | 1.2.3.3 | **ME tasks** |  | 1d? | 2005-08-01 | 2005-08-01 |  | 273d |  |  |  | 80h |
| 94 | 1.2.3.3.1 | Build homing target/dock |  | 1d? | 2005-08-01 | 2005-08-01 |  | 273d |  |  |  |  |
| 95 | 1.2.3.3.2 | Install cameras and lights |  | 1d? | 2005-08-01 | 2005-08-01 |  | 273d |  |  |  |  |
| 96 | 1.2.3.3.3 | run tests |  | 1d? | 2005-08-01 | 2005-08-01 |  | 273d |  |  |  | 32h |
| 97 | 1.2.3.3.4 | Management |  | 1d? | 2005-08-01 | 2005-08-01 |  | 273d |  |  |  | 48h |
| 98 | 1.2.3.4 | **Machine Shop** |  | 15d? | 2005-08-01 | 2005-08-19 |  | 259d |  |  |  | 120h |
| 99 | 1.2.3.4.1 | Fabricate dock, PV |  | 15d? | 2005-08-01 | 2005-08-19 |  | 259d |  |  | MS | 120h |
| 100 | 1.2.3.5 | Task complete | milestone | 0d | 2006-04-14 | 2006-04-14 | 84 | 90d |  | start no earlier than 2006-04-14 |  |  |
| 101 | 1.2.4 | **M3: Demo docking offshore** |  | 96d? | 2006-04-14 | 2006-08-25 | 83 | 26d | 0d |  |  | 736h |
| 102 | 1.2.4.1 | **EE** |  | 6d? | 2006-04-14 | 2006-04-21 |  | 90d |  |  |  | 88h |
| 103 | 1.2.4.1.1 | assemble buoy electronics |  | 3d? | 2006-04-14 | 2006-04-18 |  | 93d |  |  | EE | 24h |
| 104 | 1.2.4.1.2 | wire up subsea camera/lights/electronics |  | 2d? | 2006-04-14 | 2006-04-17 |  | 94d |  |  | EE | 16h |
| 105 | 1.2.4.1.3 | Assist with tests |  | 6d? | 2006-04-14 | 2006-04-21 |  | 90d |  |  | EE | 48h |

| ID | WBS | Task | Type | Duration | Start | Finish | Predecessors | Total slack | Free slack | Constraint | Resources | Work |
| --- | --- | --- | --- | --- | --- | --- | --- | --- | --- | --- | --- | --- |
| 106 | 1.2.4.2 | **SE** |  | 10d? | 2006-04-14 | 2006-04-27 |  | 112d |  |  |  | 208h |
| 107 | 1.2.4.2.1 | Refine homing algorithm and docking software |  | 10d? | 2006-04-14 | 2006-04-27 |  | 112d |  |  | SE | 80h |
| 108 | 1.2.4.2.2 | Modify software for rotating dock |  | 5d? | 2006-04-14 | 2006-04-20 |  | 117d |  |  | SE | 40h |
| 109 | 1.2.4.2.3 | Refine altitude controller |  | 5d? | 2006-04-14 | 2006-04-20 |  | 117d |  |  | SE | 40h |
| 110 | 1.2.4.2.4 | Perform tests |  | 1d? | 2006-04-14 | 2006-04-14 |  | 121d |  |  |  | 48h |
| 111 | 1.2.4.3 | **ME** |  | 20d? | 2006-04-14 | 2006-05-11 |  | 102d |  |  |  | 360h |
| 112 | 1.2.4.3.1 | Design and build prototype dock |  | 20d? | 2006-04-14 | 2006-05-11 |  | 102d |  |  | ME | 160h |
| 113 | 1.2.4.3.2 | Design and build comms buoy and mooring |  | 10d? | 2006-04-14 | 2006-04-27 |  | 112d |  |  | ME | 80h |
| 114 | 1.2.4.3.3 | deploy dock |  | 1d? | 2006-04-14 | 2006-04-14 |  | 121d |  |  | ME | 8h |
| 115 | 1.2.4.3.4 | run tests |  | 3d? | 2006-04-14 | 2006-04-18 |  | 119d |  |  | ME | 24h |
| 116 | 1.2.4.3.5 | rework and retest |  | 3d? | 2006-04-14 | 2006-04-18 |  | 119d |  |  | ME | 24h |
| 117 | 1.2.4.3.6 | management |  | 8d? | 2006-04-14 | 2006-04-25 |  | 114d |  |  | ME | 64h |
| 118 | 1.2.4.4 | **Machine Shop** |  | 10d? | 2006-04-14 | 2006-04-27 |  | 112d |  |  |  | 80h |
| 119 | 1.2.4.4.1 | Fabricate buoy parts, cone assy, dock base |  | 10d? | 2006-04-14 | 2006-04-27 |  | 112d |  |  | MS | 80h |
| 120 | 1.2.4.5 | Task complete | milestone | 0d | 2006-08-25 | 2006-08-25 | 102 | 0d |  | must finish on 2006-08-25 |  |  |
| 121 | 1.2.5 | **M4: Critical Design Review** |  | 25d? | 2006-08-25 | 2006-10-02 | 101 | 24d | 0d |  |  | 696h |
| 122 | 1.2.5.1 | EE |  | 8d? | 2006-08-28 | 2006-09-06 |  | 41d | 17d |  | EE | 64h |
| 123 | 1.2.5.2 | Refine electronics design |  | 1d? | 2006-08-28 | 2006-08-28 |  | 48d |  |  |  | 64h |
| 124 | 1.2.5.3 | document design and prepare CDR pres |  | 1d? | 2006-08-28 | 2006-08-28 |  | 48d |  |  |  |  |
| 125 | 1.2.5.4 | SE |  | 14d? | 2006-08-28 | 2006-09-14 |  | 35d |  |  | SE | 112h |
| 126 | 1.2.5.5 | Refine software designs |  | 1d? | 2006-08-28 | 2006-08-28 |  | 48d |  |  |  | 80h |
| 127 | 1.2.5.6 | document design and prepare CDR pres |  | 1d? | 2006-08-28 | 2006-08-28 |  | 48d |  |  |  | 32h |
| 128 | 1.2.5.7 | ME |  | 23d? | 2006-08-28 | 2006-09-27 |  | 26d |  |  | ME | 184h |
| 129 | 1.2.5.8 | Rework design and update prints |  | 1d? | 2006-08-28 | 2006-08-28 |  | 48d |  |  |  | 120h |
| 130 | 1.2.5.9 | Prepare CDR pres |  | 1d? | 2006-08-28 | 2006-08-28 |  | 48d |  |  |  | 40h |
| 131 | 1.2.5.10 | management |  | 1d? | 2006-08-28 | 2006-08-28 |  | 48d |  |  |  |  |
| 132 | 1.2.5.11 | Machine Shop | milestone | 0d? | 2006-08-25 | 2006-08-25 |  | 49d |  |  |  |  |
| 135 | 1.2.5.12 | Task complete | milestone | 0d | 2006-10-02 | 2006-10-02 | 122 | 24d |  | start no earlier than 2006-10-02 |  |  |

| ID | WBS | Task | Type | Duration | Start | Finish | Predecessors | Total slack | Free slack | Constraint | Resources | Work |
| --- | --- | --- | --- | --- | --- | --- | --- | --- | --- | --- | --- | --- |
| 136 | 1.2.6 | **M5: Operational Dock and AUV Docking Module** |  | 54d? | 2006-10-02 | 2006-12-15 | 121 | 0d |  |  |  | 584h |
| 137 | 1.2.6.1 | EE |  | 14d? | 2006-10-02 | 2006-10-19 |  | 40d |  |  | EE | 112h |
| 138 | 1.2.6.2 | SE |  | 14d? | 2006-10-02 | 2006-10-19 |  | 40d |  |  | SE | 112h |
| 139 | 1.2.6.3 | ME |  | 30d? | 2006-10-02 | 2006-11-10 |  | 24d |  |  | ME | 240h |
| 140 | 1.2.6.4 | Machine Shop |  | 15d? | 2006-10-02 | 2006-10-20 |  | 39d |  |  | MS | 120h |
| 141 | 1.2.6.5 | Task complete | milestone | 0d | 2006-12-15 | 2006-12-15 | 137 | 0d |  | start no earlier than 2006-12-15 |  |  |
| 143 | 1.2.7 | Build test mid-section |  | 1d? | 2005-08-01 | 2005-08-01 |  | 358d |  |  |  |  |
| 144 | 1.2.8 | Tank testing of latching & alignment mechanisms |  | 1d? | 2005-08-01 | 2005-08-01 |  | 358d |  |  |  |  |
| 145 | 1.2.9 | Downs-select dock |  | 1d? | 2005-08-01 | 2005-08-01 |  | 358d |  |  |  |  |
| 146 | 1.2.10 | Critical DR for dock and midbody |  | 1d? | 2005-08-01 | 2005-08-01 |  | 358d |  |  |  |  |
| 147 | 1.2.11 | Build test vehicle mid-body (borrow spare tail) |  | 1d? | 2005-08-01 | 2005-08-01 |  | 358d |  |  |  |  |
| 148 | 1.2.12 | Build test dock |  | 1d? | 2005-08-01 | 2005-08-01 |  | 358d |  |  |  |  |
| 149 | 1.2.13 | Tank test, Ocean test |  | 1d? | 2005-08-01 | 2005-08-01 |  | 358d |  |  |  |  |
| 150 | 1.2.14 | **Tail Section** |  | 16.88d | 2005-08-01 | 2005-08-23 |  | 342.12d |  |  |  | 612h |
| 151 | 1.2 | **Tail Section Electrical/Mechanical Integration & Test** |  | 16.88d | 2005-08-01 | 2005-08-23 |  | 342.12d |  |  | AUV Fabricator #1 | 612h |
| 152 | 1.2.1 | **Tail Bracketry Fabrication** |  | 4.5d | 2005-08-01 | 2005-08-05 |  | 353.38d | 11.25d |  | AUV Fabricator #1 | 126h |
| 153 | 1.2.1.1 | Forward Plate |  | 1.12d | 2005-08-01 | 2005-08-02 |  | 356.75d |  |  | AUV Fabricator #1 | 9h |
| 154 | 1.2.1.2 | Bottom Plate |  | 2.25d | 2005-08-01 | 2005-08-03 |  | 355.62d |  |  | AUV Fabricator #1 | 18h |
| 155 | 1.2.1.3 | Aft Plate |  | 1.12d | 2005-08-01 | 2005-08-02 |  | 356.75d |  |  | AUV Fabricator #1 | 9h |
| 156 | 1.2.1.4 | Mounting Clamps (DVL,parosci,homerpro,xpndr) |  | 4.5d | 2005-08-01 | 2005-08-05 |  | 353.38d |  |  | AUV Fabricator #1 | 36h |
| 157 | 1.2.1.5 | Antenna/strobe mount |  | 2.25d | 2005-08-01 | 2005-08-03 |  | 355.62d |  |  | AUV Fabricator #1 | 18h |
| 158 | 1.2.2 | Propulsion Integration/Installation |  | 5.62d | 2005-08-01 | 2005-08-08 |  | 352.25d | 10.12d |  | AUV Fabricator #1 | 45h |
| 159 | 1.2.3 | **MVC Sphere/Dry Integration** |  | 15.75d | 2005-08-01 | 2005-08-22 |  | 342.12d | 0d |  | AUV Fabricator #1 | 252h |
| 160 | 1.2.3.1 | Threaded Insert Frame Fabrication |  | 1.12d | 2005-08-01 | 2005-08-02 |  | 342.12d | 0d |  | AUV Fabricator #1 | 9h |
| 161 | 1.2.3.2 | Urethane Base Molding |  | 1.12d | 2005-08-02 | 2005-08-03 | 160 | 342.12d | 0d |  | AUV Fabricator #1 | 9h |
| 162 | 1.2.3.3 | Mounting Plate Installation |  | 1.12d | 2005-08-03 | 2005-08-04 | 161 | 342.12d | 0d |  | AUV Fabricator #1 | 9h |
| 163 | 1.2.3.4 | PC104 Stack Installation |  | 0.28d | 2005-08-04 | 2005-08-04 | 162 | 342.12d | 0d |  | AUV Fabricator #1 | 2.25h |
| 164 | 1.2.3.5 | Novatech Installation |  | 0.28d | 2005-08-04 | 2005-08-04 | 163 | 342.12d | 0d |  | AUV Fabricator #1 | 2.25h |
| 165 | 1.2.3.6 | GPS Installation |  | 0.28d | 2005-08-04 | 2005-08-05 | 164 | 342.12d | 0d |  | AUV Fabricator #1 | 2.25h |
| 166 | 1.2.3.7 | Heading Reference Installation |  | 0.28d | 2005-08-05 | 2005-08-05 | 165 | 342.12d | 0d |  | AUV Fabricator #1 | 2.25h |
| 167 | 1.2.3.8 | RF Penetrator Installation/Wiring |  | 0.56d | 2005-08-05 | 2005-08-08 | 166 | 342.12d | 0d |  | AUV Fabricator #1 | 4.5h |
| 168 | 1.2.3.9 | MINK Penetrator Installation/Wiring |  | 2.25d | 2005-08-08 | 2005-08-10 | 167 | 342.12d | 0d |  | AUV Fabricator #1 | 18h |
| 169 | 1.2.3.10 | LPBH Installation/Wiring |  | 2.25d | 2005-08-10 | 2005-08-12 | 168 | 342.12d | 0d |  | AUV Fabricator #1 | 18h |
| 170 | 1.2.3.11 | MVC Power Board Installation |  | 0.56d | 2005-08-12 | 2005-08-15 | 169 | 342.12d | 0d |  | AUV Fabricator #1 | 4.5h |
| 171 | 1.2.3.12 | Point-to-Point Wiring Installation |  | 5.62d | 2005-08-15 | 2005-08-22 | 170 | 342.12d |  |  | AUV Fabricator #1 | 45h |

| ID | WBS | Task | Type | Duration | Start | Finish | Predecessors | Total slack | Free slack | Resources | Work |
| --- | --- | --- | --- | --- | --- | --- | --- | --- | --- | --- | --- |
| 172 | 1.2.4 | **Mechanical/Wet Integration** |  | 2.25d | 2005-08-01 | 2005-08-03 |  | 355.62d | 13.5d | AUV Fabricator #1 | 36h |
| 173 | 1.2.4.1 | Mount Sphere to base plate |  | 1.12d | 2005-08-01 | 2005-08-02 |  | 355.62d | 0d | AUV Fabricator #1 | 9h |
| 174 | 1.2.4.2 | Mount/cable Parosci, HomerPro |  | 0.28d | 2005-08-02 | 2005-08-02 | 173 | 355.62d | 0d | AUV Fabricator #1 | 2.25h |
| 175 | 1.2.4.3 | Mount USBL Beacon/Transducer |  | 0.28d | 2005-08-02 | 2005-08-02 | 174 | 355.62d | 0d | AUV Fabricator #1 | 2.25h |
| 176 | 1.2.4.4 | Mount/Cable DVL |  | 0.28d | 2005-08-02 | 2005-08-02 | 175 | 355.62d | 0d | AUV Fabricator #1 | 2.25h |
| 177 | 1.2.4.5 | Syntactic Installation |  | 0.28d | 2005-08-02 | 2005-08-03 | 176 | 355.62d |  | AUV Fabricator #1 | 2.25h |
| 178 | 1.2.5 | **Functional test of Tail Section sub-systems** |  | 1.12d | 2005-08-22 | 2005-08-23 | 152, 158, 159, 172 | 342.12d |  | AUV Fabricator #1 | 18h |
| 179 | 1.2.5.1 | Tailcone Calibration |  | 0.28d | 2005-08-22 | 2005-08-23 |  | 342.12d | 0d | AUV Fabricator #1 | 2.25h |
| 180 | 1.2.5.2 | DVL Comms and Rub Test |  | 0.28d | 2005-08-23 | 2005-08-23 | 179 | 342.12d | 0d | AUV Fabricator #1 | 2.25h |
| 181 | 1.2.5.3 | Parosci Test |  | 0.28d | 2005-08-23 | 2005-08-23 | 180 | 342.12d | 0d | AUV Fabricator #1 | 2.25h |
| 182 | 1.2.5.4 | Crossbow comms test |  | 0.28d | 2005-08-23 | 2005-08-23 | 181 | 342.12d |  | AUV Fabricator #1 | 2.25h |
| 183 | 1.2.15 | **Mid body** |  | 42d | 2005-08-01 | 2005-09-27 |  | 317d |  |  | 536.95h |
| 184 | 1.1.4 | **Syntactic Fabrication** |  | 0.28d | 2005-08-01 | 2005-08-01 |  | 358.72d |  | AUV Fabricator #1 | 6.75h |
| 185 | 1.1.4.1 | Drawing Package Preparation |  | 0.28d | 2005-08-01 | 2005-08-01 |  | 358.72d |  | AUV Fabricator #1 | 2.25h |
| 186 | 1.1.4.2 | Vendor Quoting/Contracting |  | 0.28d | 2005-08-01 | 2005-08-01 |  | 358.72d |  | AUV Fabricator #1 | 2.25h |
| 187 | 1.1.4.3 | Syntactic Module Fabrication | milestone | 0d | 2005-08-01 | 2005-08-01 |  | 359d |  | AUV Fabricator #1 |  |
| 188 | 1.1.5 | **Custom Printed Circuit Board Fabrication** |  | 2.25d | 2005-08-01 | 2005-08-03 |  | 356.75d |  | AUV Fabricator #1 | 61.2h |
| 189 | 1.1.5.1 | **MVC Power Board Fabrication** |  | 2.25d | 2005-08-01 | 2005-08-03 |  | 356.75d |  | AUV Fabricator #1 | 42.75h |
| 190 | 1.1.5.1.1 | Component ordering |  | 0.28d | 2005-08-01 | 2005-08-01 |  | 358.72d |  | AUV Fabricator #1 | 2.25h |
| 191 | 1.1.5.1.2 | Component installation |  | 2.25d | 2005-08-01 | 2005-08-03 |  | 356.75d |  | AUV Fabricator #1 | 18h |
| 192 | 1.1.5.1.3 | Burn-in & test |  | 0.56d | 2005-08-01 | 2005-08-01 |  | 358.44d |  | AUV Fabricator #1 | 4.5h |
| 193 | 1.1.5.2 | Junction Box PCB Fabrication |  | 0.06d | 2005-08-01 | 2005-08-01 |  | 358.94d |  | AUV Fabricator #1 | 0.45h |
| 194 | 1.3 | **Mid Section Electrical/Mechanical Integration & Test** |  | 9d | 2005-08-01 | 2005-08-11 |  | 350d |  | AUV Fabricator #1 | 189h |
| 195 | 1.3.1 | **Bracketry** |  | 9d | 2005-08-01 | 2005-08-11 |  | 350d |  | AUV Fabricator #1 | 72h |
| 196 | 1.3.1.1 | Bracketry Fabrication |  | 9d | 2005-08-01 | 2005-08-11 |  | 350d |  |  |  |
| 197 | 1.3.1.2 | Bracketry assembly |  | 2.25d | 2005-08-01 | 2005-08-03 |  | 356.75d |  |  |  |
| 198 | 1.3.2 | Syntactic Assembly |  | 1.12d | 2005-08-01 | 2005-08-02 |  | 357.88d |  | AUV Fabricator #1 | 9h |

| ID | WBS | Task | Duration | Start | Finish | Predecessors | Total slack | Free slack | Resources | Work |
| --- | --- | --- | --- | --- | --- | --- | --- | --- | --- | --- |
| 199 | 1.3.3 | **Battery** | 2.25d | 2005-08-01 | 2005-08-03 |  | 356.75d |  | AUV Fabricator #1 | 18h |
| 200 | 1.3.3.1 | Bench testing | 2.25d | 2005-08-01 | 2005-08-03 |  | 356.75d |  |  |  |
| 201 | 1.3.3.2 | Installation | 1.12d | 2005-08-01 | 2005-08-02 |  | 357.88d |  |  |  |
| 202 | 1.3.4 | **junction Box** | 2.25d | 2005-08-01 | 2005-08-03 |  | 356.75d |  | AUV Fabricator #1 | 18h |
| 203 | 1.3.4.1 | Assembly | 2.25d | 2005-08-01 | 2005-08-03 |  | 356.75d |  |  |  |
| 204 | 1.3.4.2 | Casting | 1.12d | 2005-08-01 | 2005-08-02 |  | 357.88d |  |  |  |
| 205 | 1.3.4.3 | Installation | 0.56d | 2005-08-01 | 2005-08-01 |  | 358.44d |  |  |  |
| 206 | 1.2.15.4 | Mid body design | 10d | 2005-08-01 | 2005-08-12 |  | 317d | 0d | Jon Erickson; Brett Hobson | 160h |
| 207 | 1.2.15.5 | **Long lead time parts** | 32d | 2005-08-15 | 2005-09-27 | 206 | 317d |  |  | 16h |
| 208 | 1.2.15.5.1 | Order | 1d | 2005-08-15 | 2005-08-15 |  | 317d | 0d | Thomas Hoover | 8h |
| 209 | 1.2.15.5.2 | Shipping time | 30d | 2005-08-16 | 2005-09-26 | 208 | 317d | 0d |  |  |
| 210 | 1.2.15.5.3 | Receive | 1d | 2005-09-27 | 2005-09-27 | 209 | 317d |  | Thomas Hoover | 8h |
| 211 | 1.2.15.6 | **Manufactured parts** | 9d | 2005-08-04 | 2005-08-16 |  | 331d | 2d |  | 16h |
| 212 | 1.2.15.6.1 | Order | 1d | 2005-08-04 | 2005-08-04 |  | 331d | 0d | Thomas Hoover | 8h |
| 213 | 1.2.15.6.2 | Shipping time | 7d | 2005-08-05 | 2005-08-15 | 212 | 331d | 0d |  |  |
| 214 | 1.2.15.6.3 | Receive | 1d | 2005-08-16 | 2005-08-16 | 213 | 331d |  | Thomas Hoover | 8h |
| 215 | 1.2.15.7 | **Raw material for in-house parts** | 9d | 2005-08-08 | 2005-08-18 |  | 329d | 0d |  | 16h |
| 216 | 1.2.15.7.1 | Order | 1d | 2005-08-08 | 2005-08-08 |  | 329d | 0d | Thomas Hoover | 8h |
| 217 | 1.2.15.7.2 | Shipping time | 7d | 2005-08-09 | 2005-08-17 | 216 | 329d | 0d |  |  |
| 218 | 1.2.15.7.3 | Receive | 1d | 2005-08-18 | 2005-08-18 | 217 | 329d |  | Thomas Hoover | 8h |
| 219 | 1.2.15.8 | Manufacture in-house parts | 9d | 2005-08-19 | 2005-08-31 | 211, 215 | 329d | 0d | Jon Erickson | 72h |
| 220 | 1.2.15.9 | Assemble unit | 7d | 2005-09-01 | 2005-09-09 | 219 | 329d |  |  |  |
| 221 | 1.2.16 | Critical Design Review for final dock | 1d? | 2005-08-01 | 2005-08-01 |  | 358d |  |  |  |
| 222 | 1.3 | **2007** | 32d? | 2005-08-01 | 2005-09-13 |  | 327d |  |  | 304h |
| 223 | 1.3.1 | Build “production” dock | 1d? | 2005-08-01 | 2005-08-01 |  | 358d |  |  |  |
| 224 | 1.3.2 | Test system connected to MARS | 1d? | 2005-08-01 | 2005-08-01 |  | 358d |  |  |  |
| 225 | 1.3.3 | Install on MARS | 1d? | 2005-08-01 | 2005-08-01 |  | 358d |  |  |  |
| 226 | 1.3.4 | Run science missions | 1d? | 2005-08-01 | 2005-08-01 |  | 358d |  |  |  |

| ID | WBS | Task | Duration | Start | Finish | Predecessors | Total slack | Free slack | Resources | Work |
| --- | --- | --- | --- | --- | --- | --- | --- | --- | --- | --- |
| 234 | 1.3.5 | **Inventory existing components** | 32d | 2005-08-01 | 2005-09-13 |  | 327d |  | Thomas | 304h |
| 235 | 1.3.5.1 | **Long lead time parts** | 32d | 2005-08-01 | 2005-09-13 |  | 327d |  |  | 16h |
| 236 | 1.3.5.1.1 | Order | 1d | 2005-08-01 | 2005-08-01 |  | 327d | 0d | Thomas Hoover | 8h |
| 237 | 1.3.5.1.2 | Shipping time | 30d | 2005-08-02 | 2005-09-12 | 236 | 327d | 0d |  |  |
| 238 | 1.3.5.1.3 | Receive | 1d | 2005-09-13 | 2005-09-13 | 237 | 327d |  | Thomas Hoover | 8h |
| 239 | 1.3.5.2 | **Manufactured parts** | 9d | 2005-08-02 | 2005-08-12 |  | 349d |  |  | 16h |
| 240 | 1.3.5.2.1 | Order | 1d | 2005-08-02 | 2005-08-02 |  | 349d | 0d | Thomas Hoover | 8h |
| 241 | 1.3.5.2.2 | Shipping time | 7d | 2005-08-03 | 2005-08-11 | 240 | 349d | 0d |  |  |
| 242 | 1.3.5.2.3 | Receive | 1d | 2005-08-12 | 2005-08-12 | 241 | 349d |  | Thomas Hoover | 8h |
| 243 | 1.3.5.3 | **Raw Material for in-house parts** | 9d | 2005-08-03 | 2005-08-15 |  | 348d |  |  | 16h |
| 244 | 1.3.5.3.1 | Order | 1d | 2005-08-03 | 2005-08-03 |  | 348d | 0d | Thomas Hoover | 8h |
| 245 | 1.3.5.3.2 | Shipping time | 7d | 2005-08-04 | 2005-08-12 | 244 | 348d | 0d |  |  |
| 246 | 1.3.5.3.3 | Receive | 1d | 2005-08-15 | 2005-08-15 | 245 | 348d |  | Thomas Hoover | 8h |
