# AUV Docking 2006

Schedule from MS Project, 2005-08-01 to 2006-12-22.
MBARI

## Calendars

- Standard: Mon-Fri 08:00-12:00, 13:00-17:00; Sat-Sun off.

## Resources

| Resource |
| --- |
| Lance |
| Brett |
| Thomas |
| Machine shop |
| Jon |
| Lance McBride |
| Thomas Hoover |
| Test Tank |
| Rob Mcewen |
| Zephyr |
| Brett Hobson |
| Jon Erickson |
| AUV Fabricator #1 |
| Mike Godin |
| Yanwu Zhang |
| Rich |
| EE |
| SE |
| ME |
| MS |
| RE |
| ET |
| MT |

## Schedule

| ID | WBS | Task | Duration | Start | Finish | Total slack | Resources | Work |
| --- | --- | --- | --- | --- | --- | --- | --- | --- |
| 1 | 1 | **AUV Docking** | 365d? | 2005-08-01 | 2006-12-22 | 0d |  | 5440h |
| 2 | 1.1 | **2006:** | 305d? | 2005-08-01 | 2006-10-02 | 60d |  | 3536h |
| 3 | 1.1.1 | **Primary tasks** | 305d? | 2005-08-01 | 2006-10-02 | 60d |  | 3536h |
| 4 | 1.1.1.1 | **M1: Latching, power and data transfer** | 10d? | 2005-08-01 | 2005-08-12 | 355d |  | 684h |
| 5 | 1.1.1.1.1 | **EE tasks** | 10d? | 2005-08-01 | 2005-08-12 | 355d |  | 684h |
| 6 | 1.1.1.1.1.1 | **Create initial dock schematics** | 2d? | 2005-08-01 | 2005-08-02 | 363d |  | 48h |
| 7 | 1.1.1.1.1.1.1 | System Level Dock Schematic | 2d? | 2005-08-01 | 2005-08-02 | 363d | EE | 16h |
| 8 | 1.1.1.1.1.1.2 | Main Dock Controller (MDC) Detailed Schematic | 2d? | 2005-08-01 | 2005-08-02 | 363d | EE | 16h |
| 9 | 1.1.1.1.1.1.3 | Cable - Dock to Shore | 0.5d? | 2005-08-01 | 2005-08-01 | 364.5d | EE | 4h |
| 10 | 1.1.1.1.1.1.4 | Cable - WiFi Antenna to MDC | 0.5d? | 2005-08-01 | 2005-08-01 | 364.5d | EE | 4h |
| 11 | 1.1.1.1.1.1.5 | Cable - Magnetic Resolver to MDC | 0.5d? | 2005-08-01 | 2005-08-01 | 364.5d | EE | 4h |
| 12 | 1.1.1.1.1.1.6 | Cable - Motor Driver to MDC | 0.5d? | 2005-08-01 | 2005-08-01 | 364.5d | EE | 4h |
| 13 | 1.1.1.1.1.2 | **Rev CTD Vehicle schematic(s)** | 2d? | 2005-08-01 | 2005-08-02 | 363d |  | 20h |
| 14 | 1.1.1.1.1.2.1 | Revised Vehicle Schematic | 2d? | 2005-08-01 | 2005-08-02 | 363d | EE | 16h |
| 15 | 1.1.1.1.1.2.2 | Cable - Power Unit to MVC | 0.5d? | 2005-08-01 | 2005-08-01 | 364.5d | EE | 4h |
| 16 | 1.1.1.1.1.3 | **Assemble mock dock and vehicle electronics** | 5d? | 2005-08-01 | 2005-08-05 | 360d |  | 184h |
| 17 | 1.1.1.1.1.3.1 | Order Parts for cables & MDC internals | 2d? | 2005-08-01 | 2005-08-02 | 363d | EE | 16h |
| 18 | 1.1.1.1.1.3.2 | wire-up and test dock electronics in mock dock | 3d? | 2005-08-01 | 2005-08-04 | 361d | EE; ET | 40h |
| 19 | 1.1.1.1.1.3.3 | mount dock electronics in housing | 3d? | 2005-08-01 | 2005-08-04 | 361d | EE; ME | 40h |
| 20 | 1.1.1.1.1.3.4 | install vehicle electonics in housing, wireup and test housing | 5d? | 2005-08-01 | 2005-08-05 | 360d | ET; EE | 64h |
| 21 | 1.1.1.1.1.3.5 | mount electronics in vehicle, wire up and test in vehicle | 2d? | 2005-08-01 | 2005-08-02 | 363d | ET; EE | 24h |
| 22 | 1.1.1.1.1.4 | run tests in tank | 6d? | 2005-08-01 | 2005-08-08 | 359d | EE | 48h |
| 23 | 1.1.1.1.1.5 | **SE tasks** | 3d? | 2005-08-01 | 2005-08-03 | 362d |  | 48h |
| 24 | 1.1.1.1.1.5.1 | write docking actuator control software | 2d? | 2005-08-01 | 2005-08-02 | 363d | SE | 16h |
| 25 | 1.1.1.1.1.5.2 | dock detect sensor interface | 1d? | 2005-08-01 | 2005-08-01 | 364d | SE | 8h |
| 26 | 1.1.1.1.1.5.3 | integrate IPT control software | 3d? | 2005-08-01 | 2005-08-03 | 362d | SE | 24h |

Notes:
- 19: RF modem, IPT hardware, IPT hardware controller

| ID | WBS | Task | Duration | Start | Finish | Total slack | Free slack | Resources | Work |
| --- | --- | --- | --- | --- | --- | --- | --- | --- | --- |
| 27 | 1.1.1.1.1.6 | **ME tasks** | 10d? | 2005-08-01 | 2005-08-12 | 355d |  |  | 312h |
| 28 | 1.1.1.1.1.6.1 | build rev1 docking tube - no cone | 4d? | 2005-08-01 | 2005-08-04 | 361d |  | ME | 32h |
| 29 | 1.1.1.1.1.6.2 | build mockup dock base | 3d? | 2005-08-01 | 2005-08-03 | 362d |  | ME | 24h |
| 30 | 1.1.1.1.1.6.3 | build and test docking actuator | 10d? | 2005-08-01 | 2005-08-12 | 355d |  | ME | 80h |
| 31 | 1.1.1.1.1.6.4 | Design build and mount D-AUV PV | 1d? | 2005-08-01 | 2005-08-01 | 364d |  |  | 80h |
| 32 | 1.1.1.1.1.6.5 | Install in 10" docking section | 1d? | 2005-08-01 | 2005-08-01 | 364d |  | ME | 8h |
| 33 | 1.1.1.1.1.6.6 | assemble mockup vehicle with docking section | 2d? | 2005-08-01 | 2005-08-02 | 363d |  | ME | 16h |
| 34 | 1.1.1.1.1.6.7 | deploy in tank and run tests | 6d? | 2005-08-01 | 2005-08-08 | 359d |  | ME | 48h |
| 35 | 1.1.1.1.1.6.8 | Management | 3d? | 2005-08-01 | 2005-08-03 | 362d |  | ME | 24h |
| 36 | 1.1.1.1.1.7 | **MS tasks** | 3d? | 2005-08-01 | 2005-08-03 | 362d |  |  | 24h |
| 37 | 1.1.1.1.1.7.1 | Fabricate actuator parts and dock parts | 3d? | 2005-08-01 | 2005-08-03 | 362d |  | MS | 24h |
| 38 | 1.1.1.2 | **M2: Demo homing accuracy offshore** | 184d? | 2005-08-01 | 2006-04-14 | 81d | 0d |  | 860h |
| 39 | 1.1.1.2.1 | **EE tasks** | 4d? | 2005-08-01 | 2005-08-04 | 261d | 180d |  | 140h |
| 40 | 1.1.1.2.1.1 | **wire up subsea camera/lights/electronics** | 2d? | 2005-08-01 | 2005-08-02 | 263d |  | EE | 76h |
| 41 | 1.1.1.2.1.1.1 | Schematic(s) for wiring | 1.5d? | 2005-08-01 | 2005-08-02 | 263.5d |  | EE | 12h |
| 42 | 1.1.1.2.1.1.2 | Order cables/parts for wiring | 1d? | 2005-08-01 | 2005-08-01 | 264d |  | EE | 8h |
| 43 | 1.1.1.2.1.1.3 | Build wire harness(es) | 2d? | 2005-08-01 | 2005-08-02 | 263d |  | EE; ET | 24h |
| 44 | 1.1.1.2.1.1.4 | Test camera/lights/electronics | 2d? | 2005-08-01 | 2005-08-02 | 263d |  | EE | 16h |
| 45 | 1.1.1.2.1.2 | Vehicle support | 1d? | 2005-08-01 | 2005-08-01 | 264d |  |  | 32h |
| 46 | 1.1.1.2.1.3 | Help with tests | 4d? | 2005-08-01 | 2005-08-04 | 261d |  | EE | 32h |
| 47 | 1.1.1.2.2 | **SE tasks** | 20d? | 2005-08-01 | 2005-08-26 | 245d |  |  | 344h |
| 48 | 1.1.1.2.2.1 | write and troubleshoot USBL interface | 7d? | 2005-08-01 | 2005-08-09 | 258d |  | SE | 56h |
| 49 | 1.1.1.2.2.2 | Develop Homing algorithm | 20d? | 2005-08-01 | 2005-08-26 | 245d |  | SE | 160h |
| 50 | 1.1.1.2.2.3 | Integrate SW into MVP, test and troubleshoot | 10d? | 2005-08-01 | 2005-08-12 | 255d |  | SE | 80h |
| 51 | 1.1.1.2.2.4 | tank test | 2d? | 2005-08-01 | 2005-08-02 | 263d |  | SE | 16h |
| 52 | 1.1.1.2.2.5 | perform offshore tests | 4d? | 2005-08-01 | 2005-08-04 | 261d |  | SE | 32h |

| ID | WBS | Task | Type | Duration | Start | Finish | Predecessors | Total slack | Free slack | Constraint | Resources | Work |
| --- | --- | --- | --- | --- | --- | --- | --- | --- | --- | --- | --- | --- |
| 53 | 1.1.1.2.3 | **ME tasks** |  | 10d? | 2005-08-01 | 2005-08-12 |  | 255d |  |  |  | 256h |
| 54 | 1.1.1.2.3.1 | Build homing target/dock |  | 10d? | 2005-08-01 | 2005-08-12 |  | 255d |  |  | ME | 80h |
| 55 | 1.1.1.2.3.2 | Install cameras and lights |  | 8d? | 2005-08-01 | 2005-08-10 |  | 257d |  |  | ME | 64h |
| 56 | 1.1.1.2.3.3 | run tests |  | 8d? | 2005-08-01 | 2005-08-10 |  | 257d |  |  | ME | 64h |
| 57 | 1.1.1.2.3.4 | Management |  | 6d? | 2005-08-01 | 2005-08-08 |  | 259d |  |  | ME | 48h |
| 58 | 1.1.1.2.4 | **Machine Shop** |  | 15d? | 2005-08-01 | 2005-08-19 |  | 250d |  |  |  | 120h |
| 59 | 1.1.1.2.4.1 | Fabricate dock, PV |  | 15d? | 2005-08-01 | 2005-08-19 |  | 250d |  |  | MS | 120h |
| 60 | 1.1.1.2.5 | Task complete | milestone | 0d | 2006-04-14 | 2006-04-14 | 39 | 81d |  | start no earlier than 2006-04-14 |  |  |
| 61 | 1.1.1.3 | **M3: Demo docking offshore** |  | 96d? | 2006-04-14 | 2006-08-25 | 38 | 10d | 0d |  |  | 1264h |
| 62 | 1.1.1.3.1 | **EE** |  | 10d? | 2006-04-14 | 2006-04-27 |  | 86d |  |  |  | 440h |
| 63 | 1.1.1.3.1.1 | **integrate IPT and DTS into deployable dock** |  | 5d? | 2006-04-14 | 2006-04-20 |  | 91d |  |  | EE | 272h |
| 64 | 1.1.1.3.1.1.1 | Revised Power Budget |  | 2d? | 2006-04-14 | 2006-04-17 |  | 94d |  |  | EE | 16h |
| 65 | 1.1.1.3.1.1.2 | **Revised schematics** |  | 2.5d? | 2006-04-14 | 2006-04-18 |  | 93.5d |  |  |  | 40h |
| 66 | 1.1.1.3.1.1.2.1 | **Dock** |  | 2.5d? | 2006-04-14 | 2006-04-18 |  | 93.5d |  |  |  | 32h |
| 67 | 1.1.1.3.1.1.2.1.1 | Revise MDC schematic for NPS system |  | 2.5d? | 2006-04-14 | 2006-04-18 |  | 93.5d |  |  | EE | 20h |
| 68 | 1.1.1.3.1.1.2.1.2 | Cable - Dock to NPS Observatory / MARS SIIM |  | 0.5d? | 2006-04-14 | 2006-04-14 |  | 95.5d |  |  | EE | 4h |
| 69 | 1.1.1.3.1.1.2.1.3 | Cable - Water Current Sensor to MDC |  | 0.5d? | 2006-04-14 | 2006-04-14 |  | 95.5d |  |  | EE | 4h |
| 70 | 1.1.1.3.1.1.2.1.4 | Cable - Acoustic Modem to MDC |  | 0.5d? | 2006-04-14 | 2006-04-14 |  | 95.5d |  |  | EE | 4h |
| 71 | 1.1.1.3.1.1.2.2 | **AUV** |  | 0.5d? | 2006-04-14 | 2006-04-14 |  | 95.5d |  |  |  | 8h |
| 72 | 1.1.1.3.1.1.2.2.1 | Cable - Acoustic Modem to MVC |  | 0.5d? | 2006-04-14 | 2006-04-14 |  | 95.5d |  |  | EE | 4h |
| 73 | 1.1.1.3.1.1.2.2.2 | Cable - USBL to MVC |  | 0.5d? | 2006-04-14 | 2006-04-14 |  | 95.5d |  |  | EE | 4h |
| 74 | 1.1.1.3.1.1.3 | **Assemble deployable dock and vehicle electronics** |  | 5d? | 2006-04-14 | 2006-04-20 |  | 91d |  |  |  | 176h |
| 75 | 1.1.1.3.1.1.3.1 | assemble modified MDC electronics |  | 5d? | 2006-04-14 | 2006-04-20 |  | 91d |  |  | EE | 40h |
| 76 | 1.1.1.3.1.1.3.2 | mount modified MDC and subsystem electronics in deployable dock |  | 3d? | 2006-04-14 | 2006-04-18 |  | 93d |  |  | EE; ME | 40h |
| 77 | 1.1.1.3.1.1.3.3 | mount IPT, DTS and subsystems in vehicle, refine buoyancy |  | 2d? | 2006-04-14 | 2006-04-17 |  | 94d |  |  | EE; Rob Mcewen; ME | 48h |
| 78 | 1.1.1.3.1.1.3.4 | wire up subsea camera/lights/electronics used in previous test |  | 2d? | 2006-04-14 | 2006-04-17 |  | 94d |  |  | EE | 16h |
| 79 | 1.1.1.3.1.1.3.5 | Test dock in lab |  | 2d? | 2006-04-14 | 2006-04-17 |  | 94d |  |  | EE | 16h |
| 80 | 1.1.1.3.1.1.3.6 | Test modified vehicle in lab |  | 2d? | 2006-04-14 | 2006-04-17 |  | 94d |  |  | EE | 16h |
| 81 | 1.1.1.3.1.2 | Test new system in test tank before deployment |  | 2d? | 2006-04-14 | 2006-04-17 |  | 94d |  |  | EE; ME | 32h |
| 82 | 1.1.1.3.1.3 | Support AUV opps |  | 7d? | 2006-04-14 | 2006-04-24 |  | 89d |  |  | EE | 56h |
| 83 | 1.1.1.3.1.4 | Assist with tests |  | 10d? | 2006-04-14 | 2006-04-27 |  | 86d |  |  | EE | 80h |

| ID | WBS | Task | Type | Duration | Start | Finish | Predecessors | Total slack | Constraint | Resources | Work |
| --- | --- | --- | --- | --- | --- | --- | --- | --- | --- | --- | --- |
| 84 | 1.1.1.3.2 | **SE** |  | 15d? | 2006-04-14 | 2006-05-04 |  | 91d |  |  | 280h |
| 85 | 1.1.1.3.2.1 | Refine homing algorithm and docking software |  | 15d? | 2006-04-14 | 2006-05-04 |  | 91d |  | SE | 120h |
| 86 | 1.1.1.3.2.2 | Modify software for rotating dock |  | 5d? | 2006-04-14 | 2006-04-20 |  | 101d |  | SE | 40h |
| 87 | 1.1.1.3.2.3 | Refine altitude controller |  | 5d? | 2006-04-14 | 2006-04-20 |  | 101d |  | SE | 40h |
| 88 | 1.1.1.3.2.4 | Perform tests |  | 1d? | 2006-04-14 | 2006-04-14 |  | 105d |  |  | 80h |
| 89 | 1.1.1.3.3 | **ME** |  | 25d? | 2006-04-14 | 2006-05-18 |  | 81d |  |  | 464h |
| 90 | 1.1.1.3.3.1 | Design and build prototype dock |  | 25d? | 2006-04-14 | 2006-05-18 |  | 81d |  | ME | 200h |
| 91 | 1.1.1.3.3.2 | Design and build comms buoy and mooring |  | 10d? | 2006-04-14 | 2006-04-27 |  | 96d |  | ME | 80h |
| 92 | 1.1.1.3.3.3 | deploy dock |  | 2d? | 2006-04-14 | 2006-04-17 |  | 104d |  | ME | 16h |
| 93 | 1.1.1.3.3.4 | run tests |  | 10d? | 2006-04-14 | 2006-04-27 |  | 96d |  | ME | 80h |
| 94 | 1.1.1.3.3.5 | rework and retest |  | 3d? | 2006-04-14 | 2006-04-18 |  | 103d |  | ME | 24h |
| 95 | 1.1.1.3.3.6 | management |  | 8d? | 2006-04-14 | 2006-04-25 |  | 98d |  | ME | 64h |
| 96 | 1.1.1.3.4 | **Machine Shop** |  | 10d? | 2006-04-14 | 2006-04-27 |  | 96d |  |  | 80h |
| 97 | 1.1.1.3.4.1 | Fabricate buoy parts, cone assy, dock base |  | 10d? | 2006-04-14 | 2006-04-27 |  | 96d |  | MS | 80h |
| 98 | 1.1.1.3.5 | Task complete | milestone | 0d | 2006-08-25 | 2006-08-25 | 62 | 0d | must finish on 2006-08-25 |  |  |
| 99 | 1.1.1.4 | **M4: Critical Design Review and operations** |  | 25d? | 2006-08-28 | 2006-10-02 | 61 | 0d |  |  | 728h |
| 100 | 1.1.1.4.1 | **EE** |  | 8d? | 2006-08-28 | 2006-09-06 |  | 17d |  |  | 296h |
| 101 | 1.1.1.4.1.1 | Refine electronics design |  | 8d? | 2006-08-28 | 2006-09-06 |  | 17d |  | EE | 64h |
| 102 | 1.1.1.4.1.2 | how to integrate FAU, WiFI cleanly |  | 3d? | 2006-08-28 | 2006-08-30 |  | 22d |  | EE; ME | 48h |
| 103 | 1.1.1.4.1.3 | Refined Dock Schematics |  | 5d? | 2006-08-28 | 2006-09-01 |  | 20d |  | EE | 40h |
| 104 | 1.1.1.4.1.4 | Refined Vehicle Schematics |  | 5d? | 2006-08-28 | 2006-09-01 |  | 20d |  | EE | 40h |
| 105 | 1.1.1.4.1.5 | Prepare CDR presentation |  | 1d? | 2006-08-28 | 2006-08-28 |  | 24d |  | EE | 8h |
| 106 | 1.1.1.4.1.6 | support operations |  | 5d? | 2006-08-28 | 2006-09-01 |  | 20d |  | EE | 40h |
| 107 | 1.1.1.4.1.7 | **AGU Paper** |  | 5d? | 2006-08-28 | 2006-09-01 |  | 20d |  |  | 56h |
| 108 | 1.1.1.4.1.7.1 | Document testing for paper at AGU |  | 5d? | 2006-08-28 | 2006-09-01 |  | 20d |  | EE | 40h |
| 109 | 1.1.1.4.1.7.2 | Present at AGU |  | 2d? | 2006-08-28 | 2006-08-29 |  | 23d |  | EE | 16h |

| ID | WBS | Task | Type | Duration | Start | Finish | Predecessors | Total slack | Constraint | Resources | Work |
| --- | --- | --- | --- | --- | --- | --- | --- | --- | --- | --- | --- |
| 110 | 1.1.1.4.2 | **SE** |  | 10d? | 2006-08-28 | 2006-09-08 |  | 15d |  |  | 152h |
| 111 | 1.1.1.4.2.1 | Refine software designs |  | 10d? | 2006-08-28 | 2006-09-08 |  | 15d |  | SE | 80h |
| 112 | 1.1.1.4.2.2 | document design and prepare CDR pres |  | 4d? | 2006-08-28 | 2006-08-31 |  | 21d |  | SE | 32h |
| 113 | 1.1.1.4.2.3 | support operations |  | 5d? | 2006-08-28 | 2006-09-01 |  | 20d |  | SE | 40h |
| 114 | 1.1.1.4.3 | **ME** |  | 15d? | 2006-08-28 | 2006-09-15 |  | 10d |  |  | 280h |
| 115 | 1.1.1.4.3.1 | Rework design and update prints |  | 15d? | 2006-08-28 | 2006-09-15 |  | 10d |  | ME | 120h |
| 116 | 1.1.1.4.3.2 | Prepare CDR pres |  | 5d? | 2006-08-28 | 2006-09-01 |  | 20d |  | ME | 40h |
| 117 | 1.1.1.4.3.3 | support operations |  | 5d? | 2006-08-28 | 2006-09-01 |  | 20d |  | ME | 40h |
| 118 | 1.1.1.4.3.4 | Management |  | 10d? | 2006-08-28 | 2006-09-08 |  | 15d |  | ME | 80h |
| 119 | 1.1.1.4.4 | Task complete | milestone | 0d | 2006-10-02 | 2006-10-02 | 100 | 0d | start no earlier than 2006-10-02 |  |  |
| 120 | 1.2 | **Optional M5: Operational Dock and Docking AUV** |  | 60d? | 2006-10-02 | 2006-12-22 | 99 | 0d |  |  | 1904h |
| 121 | 1.2.1 | **EE** |  | 60d? | 2006-10-02 | 2006-12-22 |  | 0d |  |  | 800h |
| 122 | 1.2.1.1 | Build Docking-AUV tail, Upgrade batteries, add science sensors |  | 60d? | 2006-10-02 | 2006-12-22 |  | 0d |  | ET | 480h |
| 123 | 1.2.1.2 | Order Dock electronic parts |  | 2d? | 2006-10-02 | 2006-10-03 |  | 58d |  | ET | 16h |
| 124 | 1.2.1.3 | install and wire up Dock electronics |  | 15d? | 2006-10-02 | 2006-10-20 |  | 45d |  | ET | 120h |
| 125 | 1.2.1.4 | power up and test |  | 5d? | 2006-10-02 | 2006-10-06 |  | 55d |  | EE; ET | 80h |
| 126 | 1.2.1.5 | rework and retest |  | 2.5d? | 2006-10-02 | 2006-10-04 |  | 57.5d |  | EE; ET | 40h |
| 127 | 1.2.1.6 | participate in shallow water tests |  | 3d? | 2006-10-02 | 2006-10-04 |  | 57d |  | EE | 24h |
| 128 | 1.2.1.7 | Install ODI cable for MARS |  | 5d? | 2006-10-02 | 2006-10-06 |  | 55d |  | ET | 40h |
| 129 | 1.2.2 | **SE** |  | 10d? | 2006-10-02 | 2006-10-13 |  | 50d |  |  | 104h |
| 130 | 1.2.2.1 | Initialize new MVC and get all software running |  | 10d? | 2006-10-02 | 2006-10-13 |  | 50d |  | SE | 80h |
| 131 | 1.2.2.2 | Clean up code |  | 3d? | 2006-10-02 | 2006-10-04 |  | 57d |  | SE | 24h |
| 132 | 1.2.3 | **ME** |  | 60d? | 2006-10-02 | 2006-12-22 |  | 0d |  |  | 840h |
| 133 | 1.2.3.1 | Build new AUV tail, midbody, and nose sections |  | 60d? | 2006-10-02 | 2006-12-22 |  | 0d |  | MT | 480h |
| 134 | 1.2.3.2 | Order Dock parts |  | 5d? | 2006-10-02 | 2006-10-06 |  | 55d |  | ME | 40h |
| 135 | 1.2.3.3 | Assemble dock |  | 15d? | 2006-10-02 | 2006-10-20 |  | 45d |  | MT | 120h |
| 136 | 1.2.3.4 | power up and test |  | 4d? | 2006-10-02 | 2006-10-05 |  | 56d |  | ME; MT | 64h |
| 137 | 1.2.3.5 | rework and retest |  | 2.5d? | 2006-10-02 | 2006-10-04 |  | 57.5d |  | ME; MT | 40h |
| 139 | 1.2.3.6 | Perform shallow water tests |  | 1.5d? | 2006-10-02 | 2006-10-03 |  | 58.5d |  | ME; MT | 24h |
| 140 | 1.2.3.7 | Install MARS cable |  | 2d? | 2006-10-02 | 2006-10-03 |  | 58d |  | MT | 16h |
| 141 | 1.2.3.8 | Management |  | 7d? | 2006-10-02 | 2006-10-10 |  | 53d |  | ME | 56h |

| ID | WBS | Task | Type | Duration | Start | Finish | Predecessors | Total slack | Resources | Work |
| --- | --- | --- | --- | --- | --- | --- | --- | --- | --- | --- |
| 142 | 1.2.4 | **Machine Shop** |  | 20d? | 2006-10-02 | 2006-10-27 |  | 40d |  | 160h |
| 143 | 1.2.4.1 | fab dock and auv parts |  | 20d? | 2006-10-02 | 2006-10-27 |  | 40d | MS | 160h |
| 144 | 1.2.5 | Task complete | milestone | 0d | 2006-12-22 | 2006-12-22 | 121 | 0d |  |  |
