# AUV Docking 2006

Schedule from MS Project, 2005-08-01 to 2006-12-22.
MBARI

## Calendars

- Standard: Mon-Fri 08:00-12:00, 13:00-17:00; Sat-Sun off.

## Resources

| Resource |
| --- |
| Lance |
| Brett |
| Thomas |
| Machine shop |
| Jon |
| Lance McBride |
| Thomas Hoover |
| Test Tank |
| Rob Mcewen |
| Zephyr |
| Brett Hobson |
| Jon Erickson |
| AUV Fabricator #1 |
| Mike Godin |
| Yanwu Zhang |
| Rich |
| EE |
| SE |
| ME |
| MS |
| RE |
| ET |
| MT |

## Schedule

| ID | WBS | Task | Duration | Start | Finish | Total slack | Resources | Work |
| --- | --- | --- | --- | --- | --- | --- | --- | --- |
| 1 | 1 | **AUV Docking** | 365d? | 2005-08-01 | 2006-12-22 | 0d |  | 4808h |
| 2 | 1.1 | **2006:** | 305d? | 2005-08-01 | 2006-10-02 | 60d |  | 2904h |
| 3 | 1.1.1 | **Primary tasks** | 305d? | 2005-08-01 | 2006-10-02 | 60d |  | 2904h |
| 4 | 1.1.1.1 | **M1: Latching, power and data transfer** | 10d? | 2005-08-01 | 2005-08-12 | 355d |  | 496h |
| 5 | 1.1.1.1.1 | **EE tasks** | 6d? | 2005-08-01 | 2005-08-08 | 359d |  | 112h |
| 6 | 1.1.1.1.1.1 | mount dock electronics in housing | 3d? | 2005-08-01 | 2005-08-03 | 362d | EE | 24h |
| 7 | 1.1.1.1.1.2 | wire-up and test dock electronics | 3d? | 2005-08-01 | 2005-08-03 | 362d | EE | 24h |
| 8 | 1.1.1.1.1.3 | install vehicle electonics in housing, wireup and test | 6d? | 2005-08-01 | 2005-08-08 | 359d | EE | 48h |
| 9 | 1.1.1.1.1.4 | run tests in tank | 2d? | 2005-08-01 | 2005-08-02 | 363d | EE | 16h |
| 10 | 1.1.1.1.2 | **SE tasks** | 3d? | 2005-08-01 | 2005-08-03 | 362d |  | 48h |
| 11 | 1.1.1.1.2.1 | write docking actuator control software | 2d? | 2005-08-01 | 2005-08-02 | 363d | SE | 16h |
| 12 | 1.1.1.1.2.2 | dock detect sensor interface | 1d? | 2005-08-01 | 2005-08-01 | 364d | SE | 8h |
| 13 | 1.1.1.1.2.3 | integrate IPT control software | 3d? | 2005-08-01 | 2005-08-03 | 362d | SE | 24h |
| 14 | 1.1.1.1.3 | **ME tasks** | 10d? | 2005-08-01 | 2005-08-12 | 355d |  | 312h |
| 15 | 1.1.1.1.3.1 | build rev1 docking tube - no cone | 4d? | 2005-08-01 | 2005-08-04 | 361d | ME | 32h |
| 16 | 1.1.1.1.3.2 | build mockup dock base | 3d? | 2005-08-01 | 2005-08-03 | 362d | ME | 24h |
| 17 | 1.1.1.1.3.3 | build and test docking actuator | 10d? | 2005-08-01 | 2005-08-12 | 355d | ME | 80h |
| 18 | 1.1.1.1.3.4 | Design build and mount D-AUV PV | 1d? | 2005-08-01 | 2005-08-01 | 364d |  | 80h |
| 19 | 1.1.1.1.3.5 | Install in 10" docking section | 1d? | 2005-08-01 | 2005-08-01 | 364d | ME | 8h |
| 20 | 1.1.1.1.3.6 | assemble mockup vehicle with docking section | 2d? | 2005-08-01 | 2005-08-02 | 363d | ME | 16h |
| 21 | 1.1.1.1.3.7 | deploy in tank and run tests | 6d? | 2005-08-01 | 2005-08-08 | 359d | ME | 48h |
| 22 | 1.1.1.1.3.8 | Management | 3d? | 2005-08-01 | 2005-08-03 | 362d | ME | 24h |
| 23 | 1.1.1.1.4 | **MS tasks** | 3d? | 2005-08-01 | 2005-08-03 | 362d |  | 24h |
| 24 | 1.1.1.1.4.1 | Fabricate actuator parts and dock parts | 3d? | 2005-08-01 | 2005-08-03 | 362d | MS | 24h |

Notes:
- 6: RF modem, IPT hardware, IPT hardware controller

| ID | WBS | Task | Type | Duration | Start | Finish | Predecessors | Total slack | Free slack | Constraint | Resources | Work |
| --- | --- | --- | --- | --- | --- | --- | --- | --- | --- | --- | --- | --- |
| 25 | 1.1.1.2 | **M2: Demo homing accuracy offshore** |  | 184d? | 2005-08-01 | 2006-04-14 |  | 81d | 0d |  |  | 808h |
| 26 | 1.1.1.2.1 | **EE tasks** |  | 4d? | 2005-08-01 | 2005-08-04 |  | 261d | 180d |  |  | 88h |
| 27 | 1.1.1.2.1.1 | wire up subsea camera/lights/electronics |  | 3d? | 2005-08-01 | 2005-08-03 |  | 262d |  |  | EE | 24h |
| 28 | 1.1.1.2.1.2 | Vehicle support |  | 1d? | 2005-08-01 | 2005-08-01 |  | 264d |  |  |  | 32h |
| 29 | 1.1.1.2.1.3 | Help with tests |  | 4d? | 2005-08-01 | 2005-08-04 |  | 261d |  |  | EE | 32h |
| 30 | 1.1.1.2.2 | **SE tasks** |  | 20d? | 2005-08-01 | 2005-08-26 |  | 245d |  |  |  | 344h |
| 31 | 1.1.1.2.2.1 | write and troubleshoot USBL interface |  | 7d? | 2005-08-01 | 2005-08-09 |  | 258d |  |  | SE | 56h |
| 32 | 1.1.1.2.2.2 | Develop Homing algorithm |  | 20d? | 2005-08-01 | 2005-08-26 |  | 245d |  |  | SE | 160h |
| 33 | 1.1.1.2.2.3 | Integrate SW into MVP, test and troubleshoot |  | 10d? | 2005-08-01 | 2005-08-12 |  | 255d |  |  | SE | 80h |
| 34 | 1.1.1.2.2.4 | tank test |  | 2d? | 2005-08-01 | 2005-08-02 |  | 263d |  |  | SE | 16h |
| 35 | 1.1.1.2.2.5 | perform offshore tests |  | 4d? | 2005-08-01 | 2005-08-04 |  | 261d |  |  | SE | 32h |
| 36 | 1.1.1.2.3 | **ME tasks** |  | 10d? | 2005-08-01 | 2005-08-12 |  | 255d |  |  |  | 256h |
| 37 | 1.1.1.2.3.1 | Build homing target/dock |  | 10d? | 2005-08-01 | 2005-08-12 |  | 255d |  |  | ME | 80h |
| 38 | 1.1.1.2.3.2 | Install cameras and lights |  | 8d? | 2005-08-01 | 2005-08-10 |  | 257d |  |  | ME | 64h |
| 39 | 1.1.1.2.3.3 | run tests |  | 8d? | 2005-08-01 | 2005-08-10 |  | 257d |  |  | ME | 64h |
| 40 | 1.1.1.2.3.4 | Management |  | 6d? | 2005-08-01 | 2005-08-08 |  | 259d |  |  | ME | 48h |
| 41 | 1.1.1.2.4 | **Machine Shop** |  | 15d? | 2005-08-01 | 2005-08-19 |  | 250d |  |  |  | 120h |
| 42 | 1.1.1.2.4.1 | Fabricate dock, PV |  | 15d? | 2005-08-01 | 2005-08-19 |  | 250d |  |  | MS | 120h |
| 43 | 1.1.1.2.5 | Task complete | milestone | 0d | 2006-04-14 | 2006-04-14 | 26 | 81d |  | start no earlier than 2006-04-14 |  |  |
| 44 | 1.1.1.3 | **M3: Demo docking offshore** |  | 96d? | 2006-04-14 | 2006-08-25 | 25 | 10d | 0d |  |  | 1056h |
| 45 | 1.1.1.3.1 | **EE** |  | 10d? | 2006-04-14 | 2006-04-27 |  | 86d |  |  |  | 232h |
| 46 | 1.1.1.3.1.1 | integrate IPT and DTS into dock |  | 1d? | 2006-04-14 | 2006-04-14 |  | 95d |  |  |  | 40h |
| 47 | 1.1.1.3.1.2 | Support AUV opps |  | 1d? | 2006-04-14 | 2006-04-14 |  | 95d |  |  |  | 56h |
| 48 | 1.1.1.3.1.3 | assemble buoy electronics |  | 5d? | 2006-04-14 | 2006-04-20 |  | 91d |  |  | EE | 40h |
| 49 | 1.1.1.3.1.4 | wire up subsea camera/lights/electronics |  | 2d? | 2006-04-14 | 2006-04-17 |  | 94d |  |  | EE | 16h |
| 50 | 1.1.1.3.1.5 | Assist with tests |  | 10d? | 2006-04-14 | 2006-04-27 |  | 86d |  |  | EE | 80h |

| ID | WBS | Task | Type | Duration | Start | Finish | Predecessors | Total slack | Constraint | Resources | Work |
| --- | --- | --- | --- | --- | --- | --- | --- | --- | --- | --- | --- |
| 51 | 1.1.1.3.2 | **SE** |  | 15d? | 2006-04-14 | 2006-05-04 |  | 91d |  |  | 280h |
| 52 | 1.1.1.3.2.1 | Refine homing algorithm and docking software |  | 15d? | 2006-04-14 | 2006-05-04 |  | 91d |  | SE | 120h |
| 53 | 1.1.1.3.2.2 | Modify software for rotating dock |  | 5d? | 2006-04-14 | 2006-04-20 |  | 101d |  | SE | 40h |
| 54 | 1.1.1.3.2.3 | Refine altitude controller |  | 5d? | 2006-04-14 | 2006-04-20 |  | 101d |  | SE | 40h |
| 55 | 1.1.1.3.2.4 | Perform tests |  | 1d? | 2006-04-14 | 2006-04-14 |  | 105d |  |  | 80h |
| 56 | 1.1.1.3.3 | **ME** |  | 25d? | 2006-04-14 | 2006-05-18 |  | 81d |  |  | 464h |
| 57 | 1.1.1.3.3.1 | Design and build prototype dock |  | 25d? | 2006-04-14 | 2006-05-18 |  | 81d |  | ME | 200h |
| 58 | 1.1.1.3.3.2 | Design and build comms buoy and mooring |  | 10d? | 2006-04-14 | 2006-04-27 |  | 96d |  | ME | 80h |
| 59 | 1.1.1.3.3.3 | deploy dock |  | 2d? | 2006-04-14 | 2006-04-17 |  | 104d |  | ME | 16h |
| 60 | 1.1.1.3.3.4 | run tests |  | 10d? | 2006-04-14 | 2006-04-27 |  | 96d |  | ME | 80h |
| 61 | 1.1.1.3.3.5 | rework and retest |  | 3d? | 2006-04-14 | 2006-04-18 |  | 103d |  | ME | 24h |
| 62 | 1.1.1.3.3.6 | management |  | 8d? | 2006-04-14 | 2006-04-25 |  | 98d |  | ME | 64h |
| 63 | 1.1.1.3.4 | **Machine Shop** |  | 10d? | 2006-04-14 | 2006-04-27 |  | 96d |  |  | 80h |
| 64 | 1.1.1.3.4.1 | Fabricate buoy parts, cone assy, dock base |  | 10d? | 2006-04-14 | 2006-04-27 |  | 96d |  | MS | 80h |
| 65 | 1.1.1.3.5 | Task complete | milestone | 0d | 2006-08-25 | 2006-08-25 | 45 | 0d | must finish on 2006-08-25 |  |  |
| 66 | 1.1.1.4 | **M4: Critical Design Review and operations** |  | 25d? | 2006-08-28 | 2006-10-02 | 44 | 0d |  |  | 544h |
| 67 | 1.1.1.4.1 | **EE** |  | 8d? | 2006-08-28 | 2006-09-06 |  | 17d |  |  | 112h |
| 68 | 1.1.1.4.1.1 | Refine electronics design |  | 8d? | 2006-08-28 | 2006-09-06 |  | 17d |  | EE | 64h |
| 69 | 1.1.1.4.1.2 | document design and prepare CDR pres |  | 1d? | 2006-08-28 | 2006-08-28 |  | 24d |  | EE | 8h |
| 70 | 1.1.1.4.1.3 | support operations |  | 5d? | 2006-08-28 | 2006-09-01 |  | 20d |  | EE | 40h |
| 71 | 1.1.1.4.2 | **SE** |  | 10d? | 2006-08-28 | 2006-09-08 |  | 15d |  |  | 152h |
| 72 | 1.1.1.4.2.1 | Refine software designs |  | 10d? | 2006-08-28 | 2006-09-08 |  | 15d |  | SE | 80h |
| 73 | 1.1.1.4.2.2 | document design and prepare CDR pres |  | 4d? | 2006-08-28 | 2006-08-31 |  | 21d |  | SE | 32h |
| 74 | 1.1.1.4.2.3 | support operations |  | 5d? | 2006-08-28 | 2006-09-01 |  | 20d |  | SE | 40h |

| ID | WBS | Task | Type | Duration | Start | Finish | Predecessors | Total slack | Constraint | Resources | Work |
| --- | --- | --- | --- | --- | --- | --- | --- | --- | --- | --- | --- |
| 75 | 1.1.1.4.3 | **ME** |  | 15d? | 2006-08-28 | 2006-09-15 |  | 10d |  |  | 280h |
| 76 | 1.1.1.4.3.1 | Rework design and update prints |  | 15d? | 2006-08-28 | 2006-09-15 |  | 10d |  | ME | 120h |
| 77 | 1.1.1.4.3.2 | Prepare CDR pres |  | 5d? | 2006-08-28 | 2006-09-01 |  | 20d |  | ME | 40h |
| 78 | 1.1.1.4.3.3 | support operations |  | 5d? | 2006-08-28 | 2006-09-01 |  | 20d |  | ME | 40h |
| 79 | 1.1.1.4.3.4 | Management |  | 10d? | 2006-08-28 | 2006-09-08 |  | 15d |  | ME | 80h |
| 80 | 1.1.1.4.4 | Task complete | milestone | 0d | 2006-10-02 | 2006-10-02 | 67 | 0d | start no earlier than 2006-10-02 |  |  |
| 81 | 1.2 | **Optional M5: Operational Dock and Docking AUV** |  | 60d? | 2006-10-02 | 2006-12-22 | 66 | 0d |  |  | 1904h |
| 82 | 1.2.1 | **EE** |  | 60d? | 2006-10-02 | 2006-12-22 |  | 0d |  |  | 800h |
| 83 | 1.2.1.1 | Build Docking-AUV tail, Upgrade batteries, add science sensors |  | 60d? | 2006-10-02 | 2006-12-22 |  | 0d |  | ET | 480h |
| 84 | 1.2.1.2 | Order Dock electronic parts |  | 2d? | 2006-10-02 | 2006-10-03 |  | 58d |  | ET | 16h |
| 85 | 1.2.1.3 | install and wire up Dock electronics |  | 15d? | 2006-10-02 | 2006-10-20 |  | 45d |  | ET | 120h |
| 86 | 1.2.1.4 | power up and test |  | 5d? | 2006-10-02 | 2006-10-06 |  | 55d |  | EE; ET | 80h |
| 87 | 1.2.1.5 | rework and retest |  | 2.5d? | 2006-10-02 | 2006-10-04 |  | 57.5d |  | EE; ET | 40h |
| 88 | 1.2.1.6 | participate in shallow water tests |  | 3d? | 2006-10-02 | 2006-10-04 |  | 57d |  | EE | 24h |
| 89 | 1.2.1.7 | Install ODI cable for MARS |  | 5d? | 2006-10-02 | 2006-10-06 |  | 55d |  | ET | 40h |
| 90 | 1.2.2 | **SE** |  | 10d? | 2006-10-02 | 2006-10-13 |  | 50d |  |  | 104h |
| 91 | 1.2.2.1 | Initialize new MVC and get all software running |  | 10d? | 2006-10-02 | 2006-10-13 |  | 50d |  | SE | 80h |
| 92 | 1.2.2.2 | Clean up code |  | 3d? | 2006-10-02 | 2006-10-04 |  | 57d |  | SE | 24h |
| 93 | 1.2.3 | **ME** |  | 60d? | 2006-10-02 | 2006-12-22 |  | 0d |  |  | 840h |
| 94 | 1.2.3.1 | Build new AUV tail, midbody, and nose sections |  | 60d? | 2006-10-02 | 2006-12-22 |  | 0d |  | MT | 480h |
| 95 | 1.2.3.2 | Order Dock parts |  | 5d? | 2006-10-02 | 2006-10-06 |  | 55d |  | ME | 40h |
| 96 | 1.2.3.3 | Assemble dock |  | 15d? | 2006-10-02 | 2006-10-20 |  | 45d |  | MT | 120h |
| 97 | 1.2.3.4 | power up and test |  | 4d? | 2006-10-02 | 2006-10-05 |  | 56d |  | ME; MT | 64h |
| 98 | 1.2.3.5 | rework and retest |  | 2.5d? | 2006-10-02 | 2006-10-04 |  | 57.5d |  | ME; MT | 40h |
| 100 | 1.2.3.6 | Perform shallow water tests |  | 1.5d? | 2006-10-02 | 2006-10-03 |  | 58.5d |  | ME; MT | 24h |
| 101 | 1.2.3.7 | Install MARS cable |  | 2d? | 2006-10-02 | 2006-10-03 |  | 58d |  | MT | 16h |
| 102 | 1.2.3.8 | Management |  | 7d? | 2006-10-02 | 2006-10-10 |  | 53d |  | ME | 56h |

| ID | WBS | Task | Type | Duration | Start | Finish | Predecessors | Total slack | Resources | Work |
| --- | --- | --- | --- | --- | --- | --- | --- | --- | --- | --- |
| 103 | 1.2.4 | **Machine Shop** |  | 20d? | 2006-10-02 | 2006-10-27 |  | 40d |  | 160h |
| 104 | 1.2.4.1 | fab dock and auv parts |  | 20d? | 2006-10-02 | 2006-10-27 |  | 40d | MS | 160h |
| 105 | 1.2.5 | Task complete | milestone | 0d | 2006-12-22 | 2006-12-22 | 82 | 0d |  |  |
