# AUV Docking Fall 06

Schedule from MS Project, 2006-01-02 to 2006-05-31, A marks actual dates.
MBARI

## Calendars

- Standard: Mon-Fri 08:00-12:00, 13:00-17:00; Sat-Sun off.

## Resources

| Resource |
| --- |
| Brett |
| Lance |
| Machine Shop |
| Farley |
| Jon |
| Thomas |
| 2nd Diver |

## Schedule

| ID | WBS | Task | Type | Duration | Start | Finish | Predecessors | Complete | Remaining | Total slack | Free slack | Constraint | Resources | Work | Actual work |
| --- | --- | --- | --- | --- | --- | --- | --- | --- | --- | --- | --- | --- | --- | --- | --- |
| 1 | 1 | **Dock Deployment** |  | 107d? | 2006-01-02 A | 2006-05-31 |  | 40% | 63.95d? | 0d |  |  |  | 1028h | 340h |
| 2 | 1.1 | **Tube/Cone** |  | 41d | 2006-03-03 A | 2006-05-01 |  | 79% | 8.79d | 22d |  |  |  | 280h | 220h |
| 3 | 1.1.1 | Design Tube/Cone parts |  | 20d | 2006-03-03 A | 2006-03-30 A |  | 100% |  |  |  | as late as possible | Jon | 160h | 160h |
| 4 | 1.1.2 | Tube/Cone parts in shop | milestone | 0d | 2006-03-31 A | 2006-03-31 A | 3 | 100% |  |  |  | must start on 2006-03-31 |  |  |  |
| 5 | 1.1.3 | Fabricate Tube/Cone parts |  | 15d | 2006-03-31 A | 2006-04-20 | 4 | 50% | 7.5d | 26d |  | start no earlier than 2006-03-31 | Machine Shop | 120h | 60h |
| 6 | 1.1.4 | Dock tube parts out of shop | milestone | 0d | 2006-05-01 | 2006-05-01 |  |  |  | 2d | 0d | start no earlier than 2006-05-01 |  |  |  |
| 7 | 1.2 | **MISO** |  | 76d? | 2006-01-02 A | 2006-04-17 |  | 75% | 19d? | 31d |  |  |  | 40h | 28h |
| 8 | 1.2.1 | **Topside** |  | 76d? | 2006-01-02 A | 2006-04-17 |  | 80% | 15.2d? | 31d |  |  |  |  |  |
| 9 | 1.2.1.1 | Spec and order server |  | 1d? | 2006-01-02 A | 2006-01-02 A |  | 100% |  |  |  |  |  |  |  |
| 10 | 1.2.1.2 | Server build/shipping |  | 7d | 2006-04-05 A | 2006-04-13 A | 9 | 100% |  |  |  | must finish on 2006-04-13 |  |  |  |
| 11 | 1.2.1.3 | Apply for IP address |  | 1d? | 2006-04-14 | 2006-04-14 | 10 |  |  | 28d | 0d |  |  |  |  |
| 12 | 1.2.1.4 | Install software, test server |  | 1d? | 2006-04-17 | 2006-04-17 | 11 |  |  | 28d |  |  |  |  |  |
| 13 | 1.2.2 | **Camera** |  | 2.5d? | 2006-04-07 A | 2006-04-11 |  | 85% | 0.38d? | 35.5d |  |  |  | 24h | 20h |
| 14 | 1.2.2.1 | modify housing |  | 1d? | 2006-04-07 A | 2006-04-07 |  | 75% | 0.25d? | 1d |  | start no earlier than 2006-04-07 | Brett | 8h | 6h |
| 15 | 1.2.2.2 | order connector |  | 1d? | 2006-04-10 A | 2006-04-10 A | 14 | 100% |  |  |  |  | Brett | 8h | 8h |
| 16 | 1.2.2.3 | install camera wire up and test |  | 0.5d? | 2006-04-11 A | 2006-04-11 | 15 | 75% | 0.12d? | 33.5d |  |  | Brett; Lance | 8h | 6h |
| 17 | 1.2.3 | Test network access at 510 |  | 1d? | 2006-04-11 A | 2006-04-12 A | 16 | 100% |  |  |  |  | Lance | 8h | 8h |
| 18 | 1.2.4 | Install camera and transponder |  | 1.33d? | 2006-04-13 | 2006-04-14 | 17 |  |  | 0d |  | as late as possible | 2nd Diver [50%]; Brett [50%] | 8h |  |
| 19 | 1.3 | Zephyr Test day |  | 1d? | 2006-04-17 | 2006-04-17 | 18 |  |  | 0d |  | must start on 2006-04-17 |  |  |  |
| 20 | 1.4 | **Dock Base** |  | 42d? | 2006-03-28 A | 2006-05-24 |  | 17% | 34.83d? | 4d |  |  |  | 232h | 56h |
| 21 | 1.4.1 | Design Base |  | 14d? | 2006-03-28 A | 2006-04-14 |  | 50% | 7d? | 30d |  | finish no earlier than 2006-04-14 | Farley | 112h | 56h |
| 22 | 1.4.2 | Mast prints in shop |  | 1d? | 2006-04-18 | 2006-04-18 |  |  |  | 1d | 0d | start no earlier than 2006-04-18 |  |  |  |
| 23 | 1.4.3 | Fabricate mast |  | 10d | 2006-04-19 | 2006-05-02 | 22 |  |  | 1d | 0d |  |  |  |  |
| 24 | 1.4.4 | Base parts in shop | milestone | 0d | 2006-05-02 | 2006-05-02 | 23 |  |  | 1d | 0d | start no earlier than 2006-04-14 |  |  |  |
| 25 | 1.4.5 | Fabricate base parts |  | 15d | 2006-05-03 | 2006-05-23 | 24 |  |  | 1d | 0d | start no earlier than 2006-04-14 | Machine Shop | 120h |  |
| 26 | 1.4.6 | Assemble and test base |  | 1d? | 2006-05-24 | 2006-05-24 | 25 |  |  | 1d |  |  |  |  |  |

| ID | WBS | Task | Type | Duration | Start | Finish | Predecessors | Complete | Remaining | Total slack | Free slack | Constraint | Resources | Work | Actual work |
| --- | --- | --- | --- | --- | --- | --- | --- | --- | --- | --- | --- | --- | --- | --- | --- |
| 27 | 1.5 | **AUV tasks** |  | 24d? | 2006-03-31 A | 2006-05-03 |  | 38% | 14.77d? | 19d |  |  |  | 96h | 36h |
| 28 | 1.5.1 | USBL arrives | milestone | 0d | 2006-05-01 | 2006-05-01 |  |  |  | 17d | 0d | start no earlier than 2006-05-01 |  |  |  |
| 29 | 1.5.2 | Modify brackets |  | 1d? | 2006-05-01 | 2006-05-01 | 28 |  |  | 17d | 0d |  | Jon [50%] | 4h |  |
| 30 | 1.5.3 | Install USBL |  | 1d? | 2006-05-02 | 2006-05-02 | 29 |  |  | 17d | 0d |  | Thomas | 8h |  |
| 31 | 1.5.4 | Design module floats |  | 1d? | 2006-03-31 A | 2006-03-31 A | 3 | 100% |  |  |  |  | Jon [50%] | 4h | 4h |
| 32 | 1.5.5 | Fabricate module floats |  | 4d | 2006-04-03 A | 2006-04-06 A | 31 | 100% |  |  |  |  | Machine Shop | 32h | 32h |
| 33 | 1.5.6 | Final AUV assembly, test and trim |  | 1d? | 2006-05-03 | 2006-05-03 | 30 |  |  | 17d |  |  | Thomas | 8h |  |
| 34 | 1.5.7 | **IPT** |  | 8d? | 2006-04-24 | 2006-05-03 |  |  |  | 2d |  |  |  | 40h |  |
| 35 | 1.5.7.1 | IPT arrives | milestone | 0d | 2006-04-24 | 2006-04-24 |  |  |  | 5d | 0d | start no earlier than 2006-04-24 |  |  |  |
| 36 | 1.5.7.2 | Benchtop IPT tests |  | 5d? | 2006-04-24 | 2006-05-03 | 35 |  |  | 2d | 0d |  | Lance | 40h |  |
| 37 | 1.6 | Assemble Dock |  | 5d | 2006-05-04 | 2006-05-10 | 6, 36 |  |  | 2d | 0d |  | Brett [50%]; Jon [50%]; Farley [50%]; Lance [50%]; Thomas [50%] | 100h |  |
| 38 | 1.7 | **Dock tests** |  | 12d? | 2006-05-10 | 2006-05-26 | 37 |  |  | 2d |  |  |  | 240h |  |
| 39 | 1.7.1 | **Tank Tests** |  | 12d? | 2006-05-10 | 2006-05-26 |  |  |  | 2d |  |  |  | 240h |  |
| 40 | 1.7.1.1 | **Test Fixtures** |  | 1d? | 2006-05-11 | 2006-05-11 |  |  |  | 13d |  |  |  | 8h |  |
| 41 | 1.7.1.1.1 | Design bridge mount |  | 1d? | 2006-05-11 | 2006-05-11 |  |  |  | 11d |  |  | Jon [50%] | 4h |  |
| 42 | 1.7.1.1.2 | modify tube for top-mount |  | 1d? | 2006-05-11 | 2006-05-11 |  |  |  | 11d |  |  | Brett [50%] | 4h |  |
| 43 | 1.7.1.2 | Begin Tests | milestone | 0d | 2006-05-10 | 2006-05-10 | 24 |  |  | 2d | 0d |  |  |  |  |
| 44 | 1.7.1.3 | Install dock in tank |  | 1d | 2006-05-11 | 2006-05-11 | 43 |  |  | 2d | 0d |  | Brett [50%]; Jon [50%]; Farley [50%]; Lance [50%]; Thomas [50%] | 20h |  |
| 45 | 1.7.1.4 | AUV in dock power and data tests |  | 5d | 2006-05-12 | 2006-05-18 | 44 |  |  | 2d | 0d |  | Brett [50%]; Jon [50%]; Farley [50%]; Lance [50%]; Thomas [50%] | 100h |  |
| 46 | 1.7.1.5 | dock entry/exit reattach tests |  | 5d | 2006-05-19 | 2006-05-25 | 45 |  |  | 2d | 0d |  | Brett [50%]; Jon [50%]; Farley [50%]; Lance [50%]; Thomas [50%] | 100h |  |
| 47 | 1.7.1.6 | Add and test swing base |  | 1d? | 2006-05-26 | 2006-05-26 | 26, 46 |  |  | 2d | 0d |  | Farley [50%]; Thomas | 12h |  |
| 48 | 1.8 | Dock ready for deployment | milestone | 0d | 2006-05-26 | 2006-05-26 | 47 |  |  | 2d |  |  |  |  |  |
| 49 | 1.9 | Dock Deployment Days |  | 2d? | 2006-05-24 | 2006-05-25 |  |  |  | 0d |  | must start on 2006-05-24 | Brett [50%]; Jon [50%]; Farley [50%]; Lance [50%]; Thomas [50%] | 40h |  |
| 50 | 1.10 | Dock Deployed | milestone | 0d | 2006-05-31 | 2006-05-31 |  |  |  | 0d |  | start no earlier than 2006-05-31 |  |  |  |
| 51 | 2 | Initial Tests |  | 1d? | 2006-01-02 | 2006-01-02 |  |  |  | 106d |  |  |  |  |  |
