# ProjectSchedule1-0_05-08-19_TTH

Schedule from MS Project, 2005-08-18 to 2005-12-21.
MBARI

## Calendars

- Standard: Mon-Fri 08:00-12:00, 13:00-17:00; Sat-Sun off.

## Resources

| Resource |
| --- |
| Thomas Hoover |
| Brett Hobson |
| Mike Godin |
| Lance McBride |
| Jon Erickson |
| Rob Mcewen |
| Yanwu Zhang |
| Test Tank |
| Zephyr |

## Schedule

| ID | WBS | Task | Duration | Start | Finish | Predecessors | Total slack | Free slack | Constraint | Resources | Work |
| --- | --- | --- | --- | --- | --- | --- | --- | --- | --- | --- | --- |
| 1 | 1 | **Systems Development** | 18d | 2005-08-18 | 2005-09-12 |  | 6d |  |  |  | 216h |
| 2 | 1.1 | **Short Range Nav** | 13d | 2005-08-18 | 2005-09-05 |  | 2d | 0d |  |  | 88h |
| 3 | 1.1.1 | **Testing of USBL systems (Linkquest and Sonardyne)** | 3d | 2005-08-18 | 2005-08-22 |  | 12d |  |  |  | 48h |
| 4 | 1.1.1.1 | Tank Testing | 1d | 2005-08-18 | 2005-08-18 |  | 12d | 0d | start no earlier than 2005-08-18 | Test Tank; Brett Hobson | 16h |
| 5 | 1.1.1.2 | Dock Testing | 2d | 2005-08-19 | 2005-08-22 | 4 | 12d |  |  | Brett Hobson; Thomas Hoover | 32h |
| 6 | 1.1.2 | **Testing of AVS (“Egg) system** | 9d | 2005-08-24 | 2005-09-05 |  | 2d |  |  |  | 40h |
| 7 | 1.1.2.1 | AVS with current mounting | 1d | 2005-08-24 | 2005-08-24 |  | 2d | 0d | start no earlier than 2005-08-24 | Thomas Hoover; Test Tank | 16h |
| 8 | 1.1.2.2 | **AVS with new mounting** | 8d | 2005-08-25 | 2005-09-05 | 7 | 2d |  |  |  | 24h |
| 9 | 1.1.2.2.1 | Order materials | 1d | 2005-08-25 | 2005-08-25 |  | 2d | 0d |  | Thomas Hoover | 8h |
| 10 | 1.1.2.2.2 | Shipping time | 5d | 2005-08-26 | 2005-09-01 | 9 | 2d | 0d |  |  |  |
| 11 | 1.1.2.2.3 | Manufacture Mount | 1d | 2005-09-01 | 2005-09-02 | 10 | 2d | 0d |  | Thomas Hoover; Mike Godin | 8h |
| 12 | 1.1.2.2.4 | Test | 1d | 2005-09-02 | 2005-09-05 | 11 | 2d |  |  | Thomas Hoover; Mike Godin; Test Tank | 8h |
| 13 | 1.2 | **Docking Connections** | 18d | 2005-08-18 | 2005-09-12 |  | 8d |  |  |  | 128h |
| 14 | 1.2.1 | **Power Connection** | 11d | 2005-08-29 | 2005-09-12 |  | 8d |  |  |  | 80h |
| 15 | 1.2.1.1 | Trip to FAU | 4d | 2005-08-29 | 2005-09-01 |  | 8d | 0d | start no earlier than 2005-08-29 | Lance McBride | 32h |
| 16 | 1.2.1.2 | Shipping time | 5d | 2005-09-02 | 2005-09-08 | 15 | 8d | 0d |  |  |  |
| 17 | 1.2.1.3 | Test power coupling in tank | 2d | 2005-09-09 | 2005-09-12 | 16 | 8d |  |  | Lance McBride; Thomas Hoover; Test Tank | 48h |
| 18 | 1.2.2 | **Communication Connection** | 13.5d | 2005-08-18 | 2005-09-06 |  | 12.5d |  |  |  | 48h |
| 19 | 1.2.2.1 | Test of WiFi with omnidirectional antenna | 2d | 2005-08-18 | 2005-08-19 |  | 12.5d | 0d | start no earlier than 2005-08-18 | Thomas Hoover; Lance McBride; Test Tank | 24h |
| 20 | 1.2.2.2 | **Test of Wifi with directional antenna and amplifier** | 11.5d | 2005-08-22 | 2005-09-06 | 19 | 12.5d |  |  |  | 24h |
| 21 | 1.2.2.2.1 | Order materials | 1d | 2005-08-22 | 2005-08-22 |  | 12.5d | 0d |  | Lance McBride | 8h |
| 22 | 1.2.2.2.2 | Shipping time | 5d | 2005-08-23 | 2005-08-29 | 21 | 12.5d | 0d |  |  |  |
| 23 | 1.2.2.2.3 | Manufacture Mount | 1d | 2005-08-29 | 2005-09-02 | 22 | 12.5d | 0d |  | Thomas Hoover; Lance McBride | 8h |
| 24 | 1.2.2.2.4 | Test | 1d | 2005-09-02 | 2005-09-06 | 23 | 12.5d |  |  | Thomas Hoover; Lance McBride; Test Tank | 8h |

| ID | WBS | Task | Duration | Start | Finish | Predecessors | Total slack | Free slack | Constraint | Resources | Work |
| --- | --- | --- | --- | --- | --- | --- | --- | --- | --- | --- | --- |
| 25 | 2 | **Software** | 59d | 2005-08-29 | 2005-11-17 |  | 23d |  |  |  | 152h |
| 26 | 2.1 | **Homing Software development and testing** | 59d | 2005-08-29 | 2005-11-17 |  | 23d |  |  |  | 152h |
| 27 | 2.1.1 | Write homing routine | 10d | 2005-08-29 | 2005-09-09 |  | 63d | 0d | start no earlier than 2005-08-29 | Rob Mcewen | 80h |
| 28 | 2.1.2 | **First Test** | 7d | 2005-09-12 | 2005-09-20 | 27 | 63d |  |  |  | 24h |
| 29 | 2.1.2.1 | Zephyr drives on bouy | 2d | 2005-09-12 | 2005-09-20 | 2 | 63d | 40d |  | Zephyr; Rob Mcewen; Brett Hobson | 24h |
| 30 | 2.1.3 | **Second Test** | 1d | 2005-11-16 | 2005-11-16 | 29 | 23d |  |  |  | 24h |
| 31 | 2.1.3.1 | Surfaced AUV drives on "dock" | 1d | 2005-11-16 | 2005-11-16 | 35 | 23d | 0d |  | Zephyr; Rob Mcewen; Brett Hobson | 24h |
| 32 | 2.1.4 | **Third test** | 1d | 2005-11-17 | 2005-11-17 | 31 | 23d |  |  |  | 24h |
| 33 | 2.1.4.1 | Submerged AUV drives on "dock" | 1d | 2005-11-17 | 2005-11-17 |  | 23d |  |  | Zephyr; Rob Mcewen; Brett Hobson | 24h |
| 34 | 3 | **Vehicle** | 58d | 2005-09-06 | 2005-11-24 |  | 2d |  |  |  | 544h |
| 35 | 3.1 | **Nose Cone** | 51d | 2005-09-06 | 2005-11-15 |  | 2d | 0d |  |  | 264h |
| 36 | 3.1.1 | Nose design | 10d | 2005-09-06 | 2005-09-19 | 2 | 2d | 0d |  | Jon Erickson; Brett Hobson | 160h |
| 37 | 3.1.2 | **Long lead time parts** | 34d | 2005-09-20 | 2005-11-04 | 36 | 2d | 0d |  |  | 16h |
| 38 | 3.1.2.1 | Order | 1d | 2005-09-20 | 2005-09-20 |  | 2d | 0d |  | Thomas Hoover | 8h |
| 39 | 3.1.2.2 | Shipping time | 30d | 2005-09-21 | 2005-11-01 | 38 | 18d | 0d |  |  |  |
| 40 | 3.1.2.3 | Receive | 1d | 2005-11-04 | 2005-11-04 | 39 | 16d |  |  | Thomas Hoover | 8h |
| 41 | 3.1.3 | **Manufactured parts** | 9d | 2005-09-21 | 2005-10-03 | 36 | 1d |  |  |  | 16h |
| 42 | 3.1.3.1 | Order | 1d | 2005-09-21 | 2005-09-21 |  | 1d | 0d |  | Thomas Hoover | 8h |
| 43 | 3.1.3.2 | Shipping time | 7d | 2005-09-22 | 2005-09-30 | 42 | 28d | 0d |  |  |  |
| 44 | 3.1.3.3 | Receive | 1d | 2005-10-03 | 2005-10-03 | 43 | 28d |  |  | Thomas Hoover | 8h |
| 45 | 3.1.4 | **Raw Material for in-house parts** | 9d | 2005-09-22 | 2005-10-04 | 36 | 0d |  |  |  | 16h |
| 46 | 3.1.4.1 | Order | 1d | 2005-09-22 | 2005-09-22 |  | 0d |  |  | Thomas Hoover | 8h |
| 47 | 3.1.4.2 | Shipping time | 7d | 2005-09-23 | 2005-10-03 | 46 | 27d | 0d |  |  |  |
| 48 | 3.1.4.3 | Receive | 1d | 2005-10-04 | 2005-10-04 | 47 | 27d |  |  | Thomas Hoover | 8h |
| 49 | 3.1.5 | Manufacture in-house parts | 7d | 2005-10-10 | 2005-10-18 | 41, 45 | 27d | 0d |  | Jon Erickson | 56h |
| 50 | 3.1.6 | Assemble unit | 7d | 2005-11-07 | 2005-11-15 | 49, 37 | 16d | 0d |  |  |  |

| ID | WBS | Task | Duration | Start | Finish | Predecessors | Total slack | Free slack | Resources | Work |
| --- | --- | --- | --- | --- | --- | --- | --- | --- | --- | --- |
| 51 | 3.2 | **Mid body** | 45d | 2005-09-23 | 2005-11-24 | 36 | 0d |  |  | 280h |
| 52 | 3.2.1 | Mid body design | 10d | 2005-09-23 | 2005-10-06 | 13, 38, 42, 46 | 0d |  | Jon Erickson; Brett Hobson | 160h |
| 53 | 3.2.2 | **Long lead time parts** | 32d | 2005-10-07 | 2005-11-21 | 52 | 19d |  |  | 16h |
| 54 | 3.2.2.1 | Order | 1d | 2005-10-07 | 2005-10-07 |  | 19d | 0d | Thomas Hoover | 8h |
| 55 | 3.2.2.2 | Shipping time | 30d | 2005-10-10 | 2005-11-18 | 54 | 19d | 0d |  |  |
| 56 | 3.2.2.3 | Receive | 1d | 2005-11-21 | 2005-11-21 | 55 | 19d |  | Thomas Hoover | 8h |
| 57 | 3.2.3 | **Manufactured parts** | 9d | 2005-09-23 | 2005-10-05 |  | 36d | 9d |  | 16h |
| 58 | 3.2.3.1 | Order | 1d | 2005-09-23 | 2005-09-23 |  | 36d | 0d | Thomas Hoover | 8h |
| 59 | 3.2.3.2 | Shipping time | 7d | 2005-09-26 | 2005-10-04 | 58 | 36d | 0d |  |  |
| 60 | 3.2.3.3 | Receive | 1d | 2005-10-05 | 2005-10-05 | 59 | 36d |  | Thomas Hoover | 8h |
| 61 | 3.2.4 | **Raw material for in-house parts** | 9d | 2005-09-26 | 2005-10-06 |  | 35d | 8d |  | 16h |
| 62 | 3.2.4.1 | Order | 1d | 2005-09-26 | 2005-09-26 |  | 35d | 0d | Thomas Hoover | 8h |
| 63 | 3.2.4.2 | Shipping time | 7d | 2005-09-27 | 2005-10-05 | 62 | 35d | 0d |  |  |
| 64 | 3.2.4.3 | Receive | 1d | 2005-10-06 | 2005-10-06 | 63 | 35d |  | Thomas Hoover | 8h |
| 65 | 3.2.5 | Manufacture in-house parts | 9d | 2005-10-19 | 2005-10-31 | 57, 61, 49 | 27d | 11d | Jon Erickson | 72h |
| 66 | 3.2.6 | Assemble unit | 7d | 2005-11-16 | 2005-11-24 | 65, 50 | 16d |  |  |  |
| 67 | 4 | Tail Cone | 1d? | 2005-11-25 | 2005-11-25 | 51 | 18d |  |  |  |
| 68 | 5 | **Dock mock-up** | 41d? | 2005-10-07 | 2005-12-02 |  | 0d |  |  | 120h |
| 69 | 5.1 | Dock Design | 1d? | 2005-10-07 | 2005-10-07 | 52 | 0d |  | Jon Erickson; Brett Hobson | 16h |
| 70 | 5.2 | **Long Lead time items** | 9d | 2005-10-10 | 2005-10-20 | 69 | 10d |  |  | 16h |
| 71 | 5.2.1 | Order | 1d | 2005-10-10 | 2005-10-10 |  | 10d | 0d | Thomas Hoover | 8h |
| 72 | 5.2.2 | Shipping time | 7d | 2005-10-11 | 2005-10-19 | 71 | 10d | 0d |  |  |
| 73 | 5.2.3 | Receive | 1d | 2005-10-20 | 2005-10-20 | 72 | 10d | 0d | Thomas Hoover | 8h |
| 74 | 5.3 | **Manufactured parts** | 9d | 2005-10-21 | 2005-11-02 | 73 | 10d |  |  | 16h |
| 75 | 5.3.1 | Order | 1d | 2005-10-21 | 2005-10-21 |  | 10d | 0d | Thomas Hoover | 8h |
| 76 | 5.3.2 | Shipping time | 7d | 2005-10-24 | 2005-11-01 | 75 | 10d | 0d |  |  |
| 77 | 5.3.3 | Receive | 1d | 2005-11-02 | 2005-11-02 | 76 | 10d | 0d | Thomas Hoover | 8h |

| ID | WBS | Task | Duration | Start | Finish | Predecessors | Total slack | Free slack | Resources | Work |
| --- | --- | --- | --- | --- | --- | --- | --- | --- | --- | --- |
| 78 | 5.4 | **Raw material for in-house parts** | 9d | 2005-11-03 | 2005-11-15 | 77 | 10d |  |  | 16h |
| 79 | 5.4.1 | Order | 1d | 2005-11-03 | 2005-11-03 |  | 10d | 0d | Thomas Hoover | 8h |
| 80 | 5.4.2 | Shipping time | 7d | 2005-11-04 | 2005-11-14 | 79 | 10d | 0d |  |  |
| 81 | 5.4.3 | Receive | 1d | 2005-11-15 | 2005-11-15 | 80 | 10d | 0d | Thomas Hoover | 8h |
| 82 | 5.5 | Manufacture in-house parts | 7d | 2005-11-16 | 2005-11-24 | 81 | 10d | 0d | Jon Erickson | 56h |
| 83 | 5.6 | Assemble mock up dock | 6d | 2005-11-25 | 2005-12-02 | 82 | 10d |  |  |  |
| 84 | 6 | **AUV Docking Tests** | 52d | 2005-10-10 | 2005-12-20 |  | 0d |  |  | 56h |
| 85 | 6.1 | Initiate Permit for placing temporary mock-up | 5d | 2005-10-10 | 2005-10-14 | 69 | 0d |  | Brett Hobson | 40h |
| 86 | 6.2 | Permit Process for placing temporary mock-up | 45d | 2005-10-17 | 2005-12-16 | 85 | 0d |  |  |  |
| 87 | 6.3 | Place mock-up in bay | 2d | 2005-12-19 | 2005-12-20 | 86, 68, 51 | 0d |  | Zephyr | 16h |
| 88 | 7 | **Test AUV with Mock-up in Bay** | 1d? | 2005-12-21 | 2005-12-21 | 84, 32 | 0d |  |  | 64h |
| 89 | 7.1 | Day 1 of testing | 1d? | 2005-12-21 | 2005-12-21 |  | 0d |  | Thomas Hoover; Brett Hobson; Mike Godin; Lance McBride; Jon Erickson; Rob Mcewen; Yanwu Zhang; Zephyr | 64h |
