# ProjectSchedule1-0_05-08-22_BH

Schedule from MS Project, 2005-08-01 to 2005-11-04.
MBARI

## Calendars

- Standard: Mon-Fri 08:00-12:00, 13:00-17:00; Sat-Sun off.

## Resources

| Resource |
| --- |
| Lance |
| Brett |
| Thomas |
| Machine shop |
| Jon |
| Lance McBride |
| Thomas Hoover |
| Test Tank |
| Rob Mcewen |
| Zephyr |
| Brett Hobson |
| Jon Erickson |
| AUV Fabricator #1 |
| Mike Godin |
| Yanwu Zhang |

## Schedule

| ID | WBS | Task | Duration | Start | Finish | Predecessors | Total slack | Free slack | Resources | Work |
| --- | --- | --- | --- | --- | --- | --- | --- | --- | --- | --- |
| 1 | 1 | **AUV Docking** | 70d? | 2005-08-01 | 2005-11-04 |  | 0d |  |  | 3064.2h |
| 2 | 1.1 | **2005 Tasks** | 70d? | 2005-08-01 | 2005-11-04 |  | 0d |  |  | 1915.25h |
| 3 | 1.1.1 | Clean up AUV lab | 5d | 2005-08-01 | 2005-08-05 |  | 65d |  | Thomas | 40h |
| 4 | 1.1.2 | **AUV Nose Section** | 16.88d | 2005-08-01 | 2005-08-23 |  | 53.12d |  |  | 179.25h |
| 5 | 1.1.2.1 | Order nose cone assembly from Bluefin | 3d | 2005-08-01 | 2005-08-03 |  | 67d |  | Brett | 24h |
| 6 | 1.4 | Nose Section Electrical/Mechanical Integration & Test | 16.88d | 2005-08-01 | 2005-08-23 |  | 53.12d |  | AUV Fabricator #1 | 135h |
| 7 | 1.1.1.2 | **Nose DCON** | 0.56d | 2005-08-01 | 2005-08-01 |  | 69.44d |  | AUV Fabricator #1 | 11.25h |
| 8 | 1.1.1.2.1 | Quoting & ordering housing | 0.28d | 2005-08-01 | 2005-08-01 |  | 69.72d |  | AUV Fabricator #1 | 2.25h |
| 9 | 1.1.1.2.2 | Penetrator/dummy kitting for pressure test | 0.56d | 2005-08-01 | 2005-08-01 |  | 69.44d |  | AUV Fabricator #1 | 4.5h |
| 10 | 1.1.2 | Fairing Fabrication/Holes | 1.12d | 2005-08-01 | 2005-08-02 |  | 68.88d |  | AUV Fabricator #1 | 9h |
| 11 | 1.1.3 | **Inventory existing components** | 32d | 2005-08-01 | 2005-09-13 |  | 38d |  | Thomas | 304h |
| 12 | 1.1.3.1 | **Long lead time parts** | 32d | 2005-08-01 | 2005-09-13 |  | 38d |  |  | 16h |
| 13 | 1.1.3.1.1 | Order | 1d | 2005-08-01 | 2005-08-01 |  | 38d | 0d | Thomas Hoover | 8h |
| 14 | 1.1.3.1.2 | Shipping time | 30d | 2005-08-02 | 2005-09-12 | 13 | 38d | 0d |  |  |
| 15 | 1.1.3.1.3 | Receive | 1d | 2005-09-13 | 2005-09-13 | 14 | 38d |  | Thomas Hoover | 8h |
| 16 | 1.1.3.2 | **Manufactured parts** | 9d | 2005-08-02 | 2005-08-12 |  | 46d | 1d |  | 16h |
| 17 | 1.1.3.2.1 | Order | 1d | 2005-08-02 | 2005-08-02 |  | 46d | 0d | Thomas Hoover | 8h |
| 18 | 1.1.3.2.2 | Shipping time | 7d | 2005-08-03 | 2005-08-11 | 17 | 46d | 0d |  |  |
| 19 | 1.1.3.2.3 | Receive | 1d | 2005-08-12 | 2005-08-12 | 18 | 46d |  | Thomas Hoover | 8h |
| 20 | 1.1.3.3 | **Raw Material for in-house parts** | 9d | 2005-08-03 | 2005-08-15 |  | 45d | 0d |  | 16h |
| 21 | 1.1.3.3.1 | Order | 1d | 2005-08-03 | 2005-08-03 |  | 45d | 0d | Thomas Hoover | 8h |
| 22 | 1.1.3.3.2 | Shipping time | 7d | 2005-08-04 | 2005-08-12 | 21 | 45d | 0d |  |  |
| 23 | 1.1.3.3.3 | Receive | 1d | 2005-08-15 | 2005-08-15 | 22 | 45d |  | Thomas Hoover | 8h |
| 24 | 1.1.4 | Manufacture in-house parts | 7d | 2005-08-16 | 2005-08-24 | 16, 20 | 45d | 0d | Jon Erickson | 56h |
| 25 | 1.1.5 | Assemble unit | 7d | 2005-08-25 | 2005-09-02 | 24 | 45d |  |  |  |
| 26 | 1.1.6 | USBL Product Evaluations | 5d | 2005-08-01 | 2005-08-05 |  | 0d |  | Thomas; Brett | 80h |
| 27 | 1.1.7 | Order USBL | 3mo | 2005-08-08 | 2005-10-28 | 26 | 0d |  |  |  |
| 28 | 1.1.8 | Assemble BOM for Docking vehicle | 3d | 2005-08-01 | 2005-08-03 |  | 67d |  | Thomas; Jon | 48h |
| 29 | 1.1.9 | Order required parts from Bluefin | 1d | 2005-08-01 | 2005-08-01 |  | 69d |  | Brett | 8h |
| 30 | 1.1.10 | Mfg. Remaining parts | 20d? | 2005-08-01 | 2005-08-26 |  | 50d |  | Machine shop | 160h |
| 31 | 1.1.11 | Fabricate deck cradle with removeable wheels | 10d? | 2005-08-01 | 2005-08-12 |  | 60d |  | Machine shop | 80h |
| 32 | 1.1.12 | Design USBL mount in new nose cone | 5d? | 2005-08-01 | 2005-08-05 |  | 55d | 0d | Jon | 40h |
| 33 | 1.1.13 | Build USBL mount and assemble nose cone | 5d? | 2005-08-08 | 2005-08-12 | 32 | 55d |  | Jon | 40h |
| 34 | 1.1.14 | Install and test USBL | 5d | 2005-10-31 | 2005-11-04 | 27, 33 | 0d |  | Thomas | 40h |
| 35 | 1.1.15 | Mount nose cone to CTD midbody/tailcone | 2d? | 2005-08-01 | 2005-08-02 |  | 68d |  | Thomas | 16h |

| ID | WBS | Task | Type | Duration | Start | Finish | Predecessors | Total slack | Free slack | Constraint | Resources | Work |
| --- | --- | --- | --- | --- | --- | --- | --- | --- | --- | --- | --- | --- |
| 36 | 1.1.16 | **Dock** |  | 39d | 2005-08-01 | 2005-09-22 |  | 31d |  |  |  | 440h |
| 37 | 1.1.16.1 | Design Test Dock |  | 20d | 2005-08-01 | 2005-08-26 |  | 50d |  |  | Jon | 160h |
| 38 | 1.1.16.2 | **Docking Connections** |  | 18d | 2005-08-18 | 2005-09-12 |  | 39d |  |  |  | 128h |
| 39 | 1.1.16.2.1 | **Power Connection** |  | 11d | 2005-08-29 | 2005-09-12 |  | 39d |  |  |  | 80h |
| 40 | 1.1.16.2.1.1 | Trip to FAU |  | 4d | 2005-08-29 | 2005-09-01 |  | 39d | 0d | start no earlier than 2005-08-29 | Thomas | 32h |
| 41 | 1.1.16.2.1.2 | Shipping time |  | 5d | 2005-09-02 | 2005-09-08 | 40 | 39d | 0d |  |  |  |
| 42 | 1.1.16.2.1.3 | Test power coupling in tank |  | 2d | 2005-09-09 | 2005-09-12 | 41 | 39d |  |  | Lance McBride; Thomas Hoover; Test Tank | 48h |
| 43 | 1.1.16.2.2 | **Communication Connection** |  | 13.5d | 2005-08-18 | 2005-09-06 |  | 43.5d |  |  |  | 48h |
| 44 | 1.1.16.2.2.1 | Test of WiFi with omnidirectional antenna |  | 2d | 2005-08-18 | 2005-08-19 |  | 43.5d | 0d | start no earlier than 2005-08-18 | Thomas Hoover; Lance McBride; Test Tank | 24h |
| 45 | 1.1.16.2.2.2 | **Test of Wifi with directional antenna and amplifier** |  | 11.5d | 2005-08-22 | 2005-09-06 | 44 | 43.5d |  |  |  | 24h |
| 46 | 1.1.16.2.2.2.1 | Order materials |  | 1d | 2005-08-22 | 2005-08-22 |  | 43.5d | 0d |  | Lance McBride | 8h |
| 47 | 1.1.16.2.2.2.2 | Shipping time |  | 5d | 2005-08-23 | 2005-08-29 | 46 | 43.5d | 0d |  |  |  |
| 48 | 1.1.16.2.2.2.3 | Manufacture Mount |  | 1d | 2005-08-29 | 2005-09-02 | 47 | 43.5d | 0d |  | Thomas Hoover; Lance McBride | 8h |
| 49 | 1.1.16.2.2.2.4 | Test |  | 1d | 2005-09-02 | 2005-09-06 | 48 | 43.5d |  |  | Thomas Hoover; Lance McBride; Test Tank | 8h |
| 50 | 1.1.16.3 | **Software** |  | 19d | 2005-08-29 | 2005-09-22 |  | 31d |  |  |  | 152h |
| 51 | 1.1.16.3.1 | **Homing Software development and testing** |  | 19d | 2005-08-29 | 2005-09-22 |  | 31d |  |  |  | 152h |
| 52 | 1.1.16.3.1.1 | Write homing routine |  | 10d | 2005-08-29 | 2005-09-09 |  | 31d | 0d | start no earlier than 2005-08-29 | Rob Mcewen | 80h |
| 53 | 1.1.16.3.1.2 | **First Test** |  | 7d | 2005-09-12 | 2005-09-20 | 52 | 31d |  |  |  | 24h |
| 54 | 1.1.16.3.1.2.1 | Zephyr drives on bouy |  | 2d | 2005-09-12 | 2005-09-20 |  | 31d | 0d |  | Zephyr; Rob Mcewen; Brett Hobson | 24h |
| 55 | 1.1.16.3.1.3 | **Second Test** |  | 1d | 2005-09-21 | 2005-09-21 | 54 | 31d |  |  |  | 24h |
| 56 | 1.1.16.3.1.3.1 | Surfaced AUV drives on "dock" |  | 1d | 2005-09-21 | 2005-09-21 |  | 31d | 0d |  | Zephyr; Rob Mcewen; Brett Hobson | 24h |
| 57 | 1.1.16.3.1.4 | **Third test** |  | 1d | 2005-09-22 | 2005-09-22 | 56 | 31d |  |  |  | 24h |
| 58 | 1.1.16.3.1.4.1 | Submerged AUV drives on "dock" |  | 1d | 2005-09-22 | 2005-09-22 |  | 31d |  |  | Zephyr; Rob Mcewen; Brett Hobson | 24h |
| 59 | 1.1.16.4 | Conceptual DR | milestone | 0d | 2005-08-01 | 2005-08-01 |  | 70d |  |  |  |  |

| ID | WBS | Task | Type | Duration | Start | Finish | Predecessors | Total slack | Free slack | Resources | Work |
| --- | --- | --- | --- | --- | --- | --- | --- | --- | --- | --- | --- |
| 60 | 1.1.17 | **Dock mock-up** |  | 50d? | 2005-08-01 | 2005-10-07 |  | 20d |  |  | 264h |
| 61 | 1.1.17.1 | Dock Design |  | 10d? | 2005-08-01 | 2005-08-12 |  | 20d | 0d | Jon Erickson; Brett Hobson | 160h |
| 62 | 1.1.17.2 | **Long Lead time items** |  | 9d | 2005-08-15 | 2005-08-25 | 61 | 20d |  |  | 16h |
| 63 | 1.1.17.2.1 | Order |  | 1d | 2005-08-15 | 2005-08-15 |  | 20d | 0d | Thomas Hoover | 8h |
| 64 | 1.1.17.2.2 | Shipping time |  | 7d | 2005-08-16 | 2005-08-24 | 63 | 20d | 0d |  |  |
| 65 | 1.1.17.2.3 | Receive |  | 1d | 2005-08-25 | 2005-08-25 | 64 | 20d | 0d | Thomas Hoover | 8h |
| 66 | 1.1.17.3 | **Manufactured parts** |  | 9d | 2005-08-26 | 2005-09-07 | 65 | 20d |  |  | 16h |
| 67 | 1.1.17.3.1 | Order |  | 1d | 2005-08-26 | 2005-08-26 |  | 20d | 0d | Thomas Hoover | 8h |
| 68 | 1.1.17.3.2 | Shipping time |  | 7d | 2005-08-29 | 2005-09-06 | 67 | 20d | 0d |  |  |
| 69 | 1.1.17.3.3 | Receive |  | 1d | 2005-09-07 | 2005-09-07 | 68 | 20d | 0d | Thomas Hoover | 8h |
| 70 | 1.1.17.4 | **Raw material for in-house parts** |  | 9d | 2005-09-08 | 2005-09-20 | 69 | 20d |  |  | 16h |
| 71 | 1.1.17.4.1 | Order |  | 1d | 2005-09-08 | 2005-09-08 |  | 20d | 0d | Thomas Hoover | 8h |
| 72 | 1.1.17.4.2 | Shipping time |  | 7d | 2005-09-09 | 2005-09-19 | 71 | 20d | 0d |  |  |
| 73 | 1.1.17.4.3 | Receive |  | 1d | 2005-09-20 | 2005-09-20 | 72 | 20d | 0d | Thomas Hoover | 8h |
| 74 | 1.1.17.5 | Manufacture in-house parts |  | 7d | 2005-09-21 | 2005-09-29 | 73 | 20d | 0d | Jon Erickson | 56h |
| 75 | 1.1.17.6 | Assemble mock up dock |  | 6d | 2005-09-30 | 2005-10-07 | 74 | 20d |  |  |  |
| 76 | 1.1.18 | **AUV Docking Tests** |  | 52d | 2005-08-01 | 2005-10-11 |  | 17d | 0d |  | 56h |
| 77 | 1.1.18.1 | Initiate Permit for placing temporary mock-up |  | 5d | 2005-08-01 | 2005-08-05 |  | 17d | 0d | Brett Hobson | 40h |
| 78 | 1.1.18.2 | Permit Process for placing temporary mock-up |  | 45d | 2005-08-08 | 2005-10-07 | 77 | 17d | 0d |  |  |
| 79 | 1.1.18.3 | Place mock-up in bay |  | 2d | 2005-10-10 | 2005-10-11 | 78 | 17d |  | Zephyr | 16h |
| 80 | 1.1.19 | **Test AUV with Mock-up in Bay** |  | 1d? | 2005-10-12 | 2005-10-12 | 76 | 17d |  |  | 64h |
| 81 | 1.1.19.1 | Day 1 of testing |  | 1d? | 2005-10-12 | 2005-10-12 |  | 17d | 0d | Thomas Hoover; Brett Hobson; Mike Godin; Lance McBride; Jon Erickson; Rob Mcewen; Yanwu Zhang; Zephyr | 64h |
| 82 | 1.1.20 | Preliminary DR for latching & alignment mechanisms | milestone | 0d | 2005-10-12 | 2005-10-12 | 81 | 17d |  |  |  |
| 83 | 1.2 | **2006:** |  | 42d? | 2005-08-01 | 2005-09-27 |  | 28d |  |  | 1148.95h |
| 84 | 1.2.1 | Build test mid-section |  | 1d? | 2005-08-01 | 2005-08-01 |  | 69d |  |  |  |
| 85 | 1.2.2 | Tank testing of latching & alignment mechanisms |  | 1d? | 2005-08-01 | 2005-08-01 |  | 69d |  |  |  |
| 86 | 1.2.3 | Downs-select dock |  | 1d? | 2005-08-01 | 2005-08-01 |  | 69d |  |  |  |
| 87 | 1.2.4 | Critical DR for dock and midbody |  | 1d? | 2005-08-01 | 2005-08-01 |  | 69d |  |  |  |
| 88 | 1.2.5 | Build test vehicle mid-body (borrow spare tail) |  | 1d? | 2005-08-01 | 2005-08-01 |  | 69d |  |  |  |

| ID | WBS | Task | Type | Duration | Start | Finish | Total slack | Free slack | Resources | Work |
| --- | --- | --- | --- | --- | --- | --- | --- | --- | --- | --- |
| 89 | 1.2.6 | **Mid body** |  | 42d | 2005-08-01 | 2005-09-27 | 28d |  |  | 536.95h |
| 90 | 1.1.4 | **Syntactic Fabrication** |  | 0.28d | 2005-08-01 | 2005-08-01 | 69.72d |  | AUV Fabricator #1 | 6.75h |
| 91 | 1.1.4.1 | Drawing Package Preparation |  | 0.28d | 2005-08-01 | 2005-08-01 | 69.72d |  | AUV Fabricator #1 | 2.25h |
| 92 | 1.1.4.2 | Vendor Quoting/Contracting |  | 0.28d | 2005-08-01 | 2005-08-01 | 69.72d |  | AUV Fabricator #1 | 2.25h |
| 93 | 1.1.4.3 | Syntactic Module Fabrication | milestone | 0d | 2005-08-01 | 2005-08-01 | 70d |  | AUV Fabricator #1 |  |
| 94 | 1.1.5 | **Custom Printed Circuit Board Fabrication** |  | 2.25d | 2005-08-01 | 2005-08-03 | 67.75d |  | AUV Fabricator #1 | 61.2h |
| 95 | 1.1.5.1 | **MVC Power Board Fabrication** |  | 2.25d | 2005-08-01 | 2005-08-03 | 67.75d |  | AUV Fabricator #1 | 42.75h |
| 96 | 1.1.5.1.1 | Component ordering |  | 0.28d | 2005-08-01 | 2005-08-01 | 69.72d |  | AUV Fabricator #1 | 2.25h |
| 97 | 1.1.5.1.2 | Component installation |  | 2.25d | 2005-08-01 | 2005-08-03 | 67.75d |  | AUV Fabricator #1 | 18h |
| 98 | 1.1.5.1.3 | Burn-in & test |  | 0.56d | 2005-08-01 | 2005-08-01 | 69.44d |  | AUV Fabricator #1 | 4.5h |
| 99 | 1.1.5.2 | Junction Box PCB Fabrication |  | 0.06d | 2005-08-01 | 2005-08-01 | 69.94d |  | AUV Fabricator #1 | 0.45h |
| 100 | 1.3 | **Mid Section Electrical/Mechanical Integration & Test** |  | 9d | 2005-08-01 | 2005-08-11 | 61d |  | AUV Fabricator #1 | 189h |
| 101 | 1.3.1 | **Bracketry** |  | 9d | 2005-08-01 | 2005-08-11 | 61d |  | AUV Fabricator #1 | 72h |
| 102 | 1.3.1.1 | Bracketry Fabrication |  | 9d | 2005-08-01 | 2005-08-11 | 61d |  |  |  |
| 103 | 1.3.1.2 | Bracketry assembly |  | 2.25d | 2005-08-01 | 2005-08-03 | 67.75d |  |  |  |
| 104 | 1.3.2 | Syntactic Assembly |  | 1.12d | 2005-08-01 | 2005-08-02 | 68.88d |  | AUV Fabricator #1 | 9h |
| 105 | 1.3.3 | **Battery** |  | 2.25d | 2005-08-01 | 2005-08-03 | 67.75d |  | AUV Fabricator #1 | 18h |
| 106 | 1.3.3.1 | Bench testing |  | 2.25d | 2005-08-01 | 2005-08-03 | 67.75d |  |  |  |
| 107 | 1.3.3.2 | Installation |  | 1.12d | 2005-08-01 | 2005-08-02 | 68.88d |  |  |  |
| 108 | 1.3.4 | **junction Box** |  | 2.25d | 2005-08-01 | 2005-08-03 | 67.75d |  | AUV Fabricator #1 | 18h |
| 109 | 1.3.4.1 | Assembly |  | 2.25d | 2005-08-01 | 2005-08-03 | 67.75d |  |  |  |
| 110 | 1.3.4.2 | Casting |  | 1.12d | 2005-08-01 | 2005-08-02 | 68.88d |  |  |  |
| 111 | 1.3.4.3 | Installation |  | 0.56d | 2005-08-01 | 2005-08-01 | 69.44d |  |  |  |
| 112 | 1.2.6.4 | Mid body design |  | 10d | 2005-08-01 | 2005-08-12 | 28d | 0d | Jon Erickson; Brett Hobson | 160h |

| ID | WBS | Task | Duration | Start | Finish | Predecessors | Total slack | Free slack | Resources | Work |
| --- | --- | --- | --- | --- | --- | --- | --- | --- | --- | --- |
| 113 | 1.2.6.5 | **Long lead time parts** | 32d | 2005-08-15 | 2005-09-27 | 112 | 28d |  |  | 16h |
| 114 | 1.2.6.5.1 | Order | 1d | 2005-08-15 | 2005-08-15 |  | 28d | 0d | Thomas Hoover | 8h |
| 115 | 1.2.6.5.2 | Shipping time | 30d | 2005-08-16 | 2005-09-26 | 114 | 28d | 0d |  |  |
| 116 | 1.2.6.5.3 | Receive | 1d | 2005-09-27 | 2005-09-27 | 115 | 28d |  | Thomas Hoover | 8h |
| 117 | 1.2.6.6 | **Manufactured parts** | 9d | 2005-08-04 | 2005-08-16 |  | 42d | 2d |  | 16h |
| 118 | 1.2.6.6.1 | Order | 1d | 2005-08-04 | 2005-08-04 |  | 42d | 0d | Thomas Hoover | 8h |
| 119 | 1.2.6.6.2 | Shipping time | 7d | 2005-08-05 | 2005-08-15 | 118 | 42d | 0d |  |  |
| 120 | 1.2.6.6.3 | Receive | 1d | 2005-08-16 | 2005-08-16 | 119 | 42d |  | Thomas Hoover | 8h |
| 121 | 1.2.6.7 | **Raw material for in-house parts** | 9d | 2005-08-08 | 2005-08-18 |  | 40d | 0d |  | 16h |
| 122 | 1.2.6.7.1 | Order | 1d | 2005-08-08 | 2005-08-08 |  | 40d | 0d | Thomas Hoover | 8h |
| 123 | 1.2.6.7.2 | Shipping time | 7d | 2005-08-09 | 2005-08-17 | 122 | 40d | 0d |  |  |
| 124 | 1.2.6.7.3 | Receive | 1d | 2005-08-18 | 2005-08-18 | 123 | 40d |  | Thomas Hoover | 8h |
| 125 | 1.2.6.8 | Manufacture in-house parts | 9d | 2005-08-19 | 2005-08-31 | 117, 121 | 40d | 0d | Jon Erickson | 72h |
| 126 | 1.2.6.9 | Assemble unit | 7d | 2005-09-01 | 2005-09-09 | 125 | 40d |  |  |  |
| 127 | 1.2.7 | **Tail Section** | 16.88d | 2005-08-01 | 2005-08-23 |  | 53.12d |  |  | 612h |
| 128 | 1.2 | **Tail Section Electrical/Mechanical Integration & Test** | 16.88d | 2005-08-01 | 2005-08-23 |  | 53.12d |  | AUV Fabricator #1 | 612h |
| 129 | 1.2.1 | **Tail Bracketry Fabrication** | 4.5d | 2005-08-01 | 2005-08-05 |  | 64.38d | 11.25d | AUV Fabricator #1 | 126h |
| 130 | 1.2.1.1 | Forward Plate | 1.12d | 2005-08-01 | 2005-08-02 |  | 67.75d |  | AUV Fabricator #1 | 9h |
| 131 | 1.2.1.2 | Bottom Plate | 2.25d | 2005-08-01 | 2005-08-03 |  | 66.62d |  | AUV Fabricator #1 | 18h |
| 132 | 1.2.1.3 | Aft Plate | 1.12d | 2005-08-01 | 2005-08-02 |  | 67.75d |  | AUV Fabricator #1 | 9h |
| 133 | 1.2.1.4 | Mounting Clamps (DVL,parosci,homerpro,xpndr) | 4.5d | 2005-08-01 | 2005-08-05 |  | 64.38d |  | AUV Fabricator #1 | 36h |
| 134 | 1.2.1.5 | Antenna/strobe mount | 2.25d | 2005-08-01 | 2005-08-03 |  | 66.62d |  | AUV Fabricator #1 | 18h |
| 135 | 1.2.2 | Propulsion Integration/Installation | 5.62d | 2005-08-01 | 2005-08-08 |  | 63.25d | 10.12d | AUV Fabricator #1 | 45h |
| 136 | 1.2.3 | **MVC Sphere/Dry Integation** | 15.75d | 2005-08-01 | 2005-08-22 |  | 53.12d | 0d | AUV Fabricator #1 | 252h |
| 137 | 1.2.3.1 | Threaded Insert Frame Fabrication | 1.12d | 2005-08-01 | 2005-08-02 |  | 53.12d | 0d | AUV Fabricator #1 | 9h |
| 138 | 1.2.3.2 | Urethane Base Molding | 1.12d | 2005-08-02 | 2005-08-03 | 137 | 53.12d | 0d | AUV Fabricator #1 | 9h |
| 139 | 1.2.3.3 | Mounting Plate Installation | 1.12d | 2005-08-03 | 2005-08-04 | 138 | 53.12d | 0d | AUV Fabricator #1 | 9h |
| 140 | 1.2.3.4 | PC104 Stack Intallation | 0.28d | 2005-08-04 | 2005-08-04 | 139 | 53.12d | 0d | AUV Fabricator #1 | 2.25h |
| 141 | 1.2.3.5 | Novatech Installation | 0.28d | 2005-08-04 | 2005-08-04 | 140 | 53.12d | 0d | AUV Fabricator #1 | 2.25h |
| 142 | 1.2.3.6 | GPS Installation | 0.28d | 2005-08-04 | 2005-08-05 | 141 | 53.12d | 0d | AUV Fabricator #1 | 2.25h |
| 143 | 1.2.3.7 | Heading Reference Installation | 0.28d | 2005-08-05 | 2005-08-05 | 142 | 53.12d | 0d | AUV Fabricator #1 | 2.25h |
| 144 | 1.2.3.8 | RF Penetrator Installation/Wiring | 0.56d | 2005-08-05 | 2005-08-08 | 143 | 53.12d | 0d | AUV Fabricator #1 | 4.5h |
| 145 | 1.2.3.9 | MINK Penetrator Installation/Wiring | 2.25d | 2005-08-08 | 2005-08-10 | 144 | 53.12d | 0d | AUV Fabricator #1 | 18h |
| 146 | 1.2.3.10 | LPBH Installation/Wiring | 2.25d | 2005-08-10 | 2005-08-12 | 145 | 53.12d | 0d | AUV Fabricator #1 | 18h |
| 147 | 1.2.3.11 | MVC Power Board Installation | 0.56d | 2005-08-12 | 2005-08-15 | 146 | 53.12d | 0d | AUV Fabricator #1 | 4.5h |
| 148 | 1.2.3.12 | Point-to-Point Wiring Installation | 5.62d | 2005-08-15 | 2005-08-22 | 147 | 53.12d |  | AUV Fabricator #1 | 45h |

| ID | WBS | Task | Duration | Start | Finish | Predecessors | Total slack | Free slack | Resources | Work |
| --- | --- | --- | --- | --- | --- | --- | --- | --- | --- | --- |
| 149 | 1.2.4 | **Mechanical/Wet Integration** | 2.25d | 2005-08-01 | 2005-08-03 |  | 66.62d | 13.5d | AUV Fabricator #1 | 36h |
| 150 | 1.2.4.1 | Mount Sphere to base plate | 1.12d | 2005-08-01 | 2005-08-02 |  | 66.62d | 0d | AUV Fabricator #1 | 9h |
| 151 | 1.2.4.2 | Mount/cable Parosci, HomerPro | 0.28d | 2005-08-02 | 2005-08-02 | 150 | 66.62d | 0d | AUV Fabricator #1 | 2.25h |
| 152 | 1.2.4.3 | Mount USBL Beacon/Transducer | 0.28d | 2005-08-02 | 2005-08-02 | 151 | 66.62d | 0d | AUV Fabricator #1 | 2.25h |
| 153 | 1.2.4.4 | Mount/Cable DVL | 0.28d | 2005-08-02 | 2005-08-02 | 152 | 66.62d | 0d | AUV Fabricator #1 | 2.25h |
| 154 | 1.2.4.5 | Syntactic Installation | 0.28d | 2005-08-02 | 2005-08-03 | 153 | 66.62d |  | AUV Fabricator #1 | 2.25h |
| 155 | 1.2.5 | **Functional test of Tail Section sub-systems** | 1.12d | 2005-08-22 | 2005-08-23 | 129, 135, 136, 149 | 53.12d |  | AUV Fabricator #1 | 18h |
| 156 | 1.2.5.1 | Tailcone Calibration | 0.28d | 2005-08-22 | 2005-08-23 |  | 53.12d | 0d | AUV Fabricator #1 | 2.25h |
| 157 | 1.2.5.2 | DVL Comms and Rub Test | 0.28d | 2005-08-23 | 2005-08-23 | 156 | 53.12d | 0d | AUV Fabricator #1 | 2.25h |
| 158 | 1.2.5.3 | Parosci Test | 0.28d | 2005-08-23 | 2005-08-23 | 157 | 53.12d | 0d | AUV Fabricator #1 | 2.25h |
| 159 | 1.2.5.4 | Crossbow comms test | 0.28d | 2005-08-23 | 2005-08-23 | 158 | 53.12d |  | AUV Fabricator #1 | 2.25h |
| 160 | 1.2.8 | Build test dock | 1d? | 2005-08-01 | 2005-08-01 |  | 69d |  |  |  |
| 161 | 1.2.9 | Tank test, Ocean test | 1d? | 2005-08-01 | 2005-08-01 |  | 69d |  |  |  |
| 162 | 1.2.10 | Critical Design Review for final dock | 1d? | 2005-08-01 | 2005-08-01 |  | 69d |  |  |  |
| 163 | 1.3 | **2007** | 1d? | 2005-08-01 | 2005-08-01 |  | 69d |  |  |  |
| 164 | 1.3.1 | Build “production” dock | 1d? | 2005-08-01 | 2005-08-01 |  | 69d |  |  |  |
| 165 | 1.3.2 | Test system connected to MARS | 1d? | 2005-08-01 | 2005-08-01 |  | 69d |  |  |  |
| 166 | 1.3.3 | Install on MARS | 1d? | 2005-08-01 | 2005-08-01 |  | 69d |  |  |  |
| 167 | 1.3.4 | Run science missions | 1d? | 2005-08-01 | 2005-08-01 |  | 69d |  |  |  |
